# Внедрение Exchange (полная версия)

How a schedule from MS Project changed from version to version. A marks actual dates.

## Version 1 (data date 2010-07-12, saved 2012-04-26, file Внедрение Exchange (полная версия).mpp)

| ID | WBS | Task | Duration | Start | Finish | Predecessors | Complete | Total float | Constraint |
| --- | --- | --- | --- | --- | --- | --- | --- | --- | --- |
| 1 |  | Начало проекта | 0d | 2010-05-10 A | 2010-05-10 A |  | 100% |  | start no earlier than 2010-05-10 |
| 2 |  | Проект завершен | 0d | 2010-10-05 | 2010-10-05 | 60, 81, 8, 16, 21, 46, 87, 31 |  | 0d |  |
| 3 | 3 | **Обученные пользователи** | 72d | 2010-05-10 A | 2010-08-17 |  | 51% | 35d |  |
| 4 | 3.1 | **Подготовить тренеров** | 12d | 2010-05-10 A | 2010-05-25 A |  | 100% |  |  |
| 5 |  | Согласовать программу обучения тренеров с Заказчиком | 2d | 2010-05-10 A | 2010-05-11 A | 1 | 100% |  |  |
| 6 |  | Подписать договор на обучение тренеров | 2d | 2010-05-10 A | 2010-05-11 A | 1 | 100% |  |  |
| 7 |  | Пройти обучение для тренеров | 10d | 2010-05-12 A | 2010-05-25 A | 5, 6 | 100% |  |  |
| 8 |  | Тренеры прошли обучение по работе с Системой | 0d | 2010-05-25 A | 2010-05-25 A | 7 | 100% |  |  |
| 9 | 3.2 | **Обучить топ-менеджеров** | 37d | 2010-05-19 A | 2010-07-08 A |  | 100% |  |  |
| 10 |  | Согласовать программу обучения топ-менеджеров с Заказчиком | 5d | 2010-05-19 A | 2010-05-25 A | 1 | 100% |  | as late as possible |
| 11 |  | Подготовить раздаточные материалы для обучения топ-менеджеров | 10d | 2010-05-26 A | 2010-06-08 A | 10, 8 | 100% |  |  |
| 12 |  | Согласовать график проведения обучения с топ-менеджерами | 5d | 2010-05-26 A | 2010-06-01 A | 8 | 100% |  |  |
| 13 |  | Провести обучение топ-менеджеров (группа 1) | 3d | 2010-06-09 A | 2010-06-11 A | 12, 11 | 100% |  |  |
| 14 |  | Провести обучение топ-менеджеров (группа 2) | 5d | 2010-06-14 A | 2010-06-18 A | 13 | 100% |  |  |
| 15 |  | Провести обучение топ-менеджеров (группа 3) | 1d | 2010-07-08 A | 2010-07-08 A | 14 | 100% |  |  |
| 16 |  | Топ-менеджеры прошли обучение | 0d | 2010-07-08 A | 2010-07-08 A | 15 | 100% |  |  |
| 17 | 3.3 | **Обучить специалистов ИТ** | 12d | 2010-08-02 | 2010-08-17 |  |  | 35d |  |
| 18 |  | Согласовать программу обучения ИТ специалистов с Заказчиком | 2d | 2010-08-02 | 2010-08-03 | 1 |  | 35d | start no earlier than 2010-08-02 |
| 19 |  | Подписать договор на обучение ИТ специалистов | 2d | 2010-08-02 | 2010-08-03 | 1 |  | 35d | start no earlier than 2010-08-02 |
| 20 |  | Пройти обучение для ИТ-специалистов | 10d | 2010-08-04 | 2010-08-17 | 19, 18 |  | 35d |  |
| 21 |  | ИТ-специалисты прошли обучение | 0d | 2010-08-17 | 2010-08-17 | 20 |  | 35d |  |
| 22 | 3.4 | **Обучить менеджеров среднего звена** | 24d | 2010-07-09 | 2010-08-11 |  |  | 39d |  |
| 23 |  | Согласовать список менеджеров среднего звена к обучению с разбиением на группы | 4d | 2010-07-09 | 2010-07-14 | 16 |  | 39d |  |
| 24 |  | Согласовать график проведения обучения с менджерами среднего звена | 4d | 2010-07-09 | 2010-07-14 | 16 |  | 39d |  |
| 25 |  | Провести обучение менеджеров среднего звена (группа 1) | 2d | 2010-07-15 | 2010-07-16 | 24, 23 |  | 39d | start no earlier than 2010-07-12 |
| 26 |  | Провести обучение менеджеров среднего звена (группа 2) | 4d | 2010-07-19 | 2010-07-22 | 25 |  | 39d |  |
| 27 |  | Провести обучение менеджеров среднего звена (группа 3) | 4d | 2010-07-23 | 2010-07-28 | 26 |  | 39d |  |
| 28 |  | Провести обучение менеджеров среднего звена (группа 4) | 3d | 2010-07-29 | 2010-08-02 | 27 |  | 39d |  |
| 29 |  | Провести обучение менеджеров среднего звена (группа 5) | 2d | 2010-08-03 | 2010-08-04 | 28 |  | 39d |  |
| 30 |  | Оценить результаты обучения менеджеров среднего звена | 5d | 2010-08-05 | 2010-08-11 | 29 |  | 39d |  |
| 31 |  | Менеджеры среднего звена прошли обучение | 0d | 2010-08-11 | 2010-08-11 | 30 |  | 39d |  |
| 32 | 4 | **Настроенная Система** | 21d | 2010-07-09 A | 2010-08-06 |  | 16% | 0d |  |
| 33 | 4.1 | **Подготовить требования к Системе** | 5d | 2010-07-09 A | 2010-07-15 A |  | 100% |  |  |
| 34 |  | Подготовить требования к настройке Системы. Направить на согласование | 2d | 2010-07-09 A | 2010-07-12 A | 16 | 100% |  |  |
| 35 |  | Согласовать требования к настройке Системы. Высказать замечания | 3d | 2010-07-13 A | 2010-07-15 A | 34 | 100% |  |  |
| 36 |  | Доработать требования к настройке Системы согласно замечаниям | 1d | 2010-07-14 A | 2010-07-15 A | 35 | 100% |  |  |
| 37 |  | Подписать требования к настройке Системы | 0d | 2010-07-15 A | 2010-07-15 A | 36 | 100% |  |  |
| 38 | 4.2 | **Настроить серверную часть** | 16d | 2010-07-16 | 2010-08-06 |  |  | 0d |  |
| 39 |  | Настроить серверную часть Календарь | 4d | 2010-07-16 | 2010-07-21 | 37 |  | 0d |  |
| 40 |  | Настроить серверную часть Почта | 4d | 2010-07-22 | 2010-07-27 | 39 |  | 0d |  |
| 41 |  | Настроить серверную часть Задачи | 4d | 2010-07-28 | 2010-08-02 | 40 |  | 0d |  |
| 42 |  | Настроить серверную часть Контакты | 4d | 2010-08-03 | 2010-08-06 | 41 |  | 0d |  |
| 43 |  | Настроить серверную часть Синхронизация и удаленный доступ | 10d | 2010-07-16 | 2010-07-29 | 37 |  | 0d |  |
| 44 |  | Настроить серверную часть Технические настройки | 4d | 2010-07-30 | 2010-08-04 | 43 |  | 0d |  |
| 45 |  | Проверить работоспособность настроенных функций | 2d | 2010-08-05 | 2010-08-06 | 44 |  | 0d |  |
| 46 |  | Серверная часть настроена в соответствии с требованиями | 0d | 2010-08-06 | 2010-08-06 | 45, 42 |  | 0d |  |
| 47 | 5 | **Документация к Системе** | 57d | 2010-07-19 | 2010-10-05 |  |  | 0d |  |
| 48 |  | Описать настройки Системы (адреса, пароли и явки) | 5d | 2010-08-09 | 2010-08-13 | 46 |  | 0d |  |
| 49 |  | Предоставить формат описания пользовательской документации | 5d | 2010-07-19 | 2010-07-23 | 1 |  | 0d | as late as possible |
| 50 |  | Разработать документацию к Системе. Календарь | 5d | 2010-07-26 | 2010-07-30 | 39, 49 |  | 0d |  |
| 51 |  | Разработать документацию к Системе. Почта | 5d | 2010-08-02 | 2010-08-06 | 50, 40 |  | 0d |  |
| 52 |  | Разработать документацию к Системе. Задачи | 5d | 2010-08-09 | 2010-08-13 | 51, 41 |  | 0d |  |
| 53 |  | Разработать документацию к Системе. Контакты | 5d | 2010-08-16 | 2010-08-20 | 52, 42 |  | 0d |  |
| 54 |  | Разработать документацию к Системе. Синхронизация и удаленный доступ | 5d | 2010-07-30 | 2010-08-05 | 43 |  | 11d |  |
| 55 |  | Разработать документацию к Системе. Администрирование и поддержка Системы | 5d | 2010-08-16 | 2010-08-20 | 48, 44 |  | 0d |  |
| 56 |  | Подписать Акт сдачи-приемки документации к Системе | 2d | 2010-08-23 | 2010-08-24 | 50, 51, 52, 53, 54, 55 |  | 0d |  |
| 57 |  | Резерв времени на разработку документации к Системе | 20d | 2010-08-25 | 2010-09-21 | 56 |  | 0d |  |
| 58 |  | Утвердить документацию к Системе на СД | 5d | 2010-09-22 | 2010-09-28 | 57 |  | 0d |  |
| 59 |  | Ознакомить пользователей с документацией к Системе | 5d | 2010-09-29 | 2010-10-05 | 58 |  | 0d |  |
| 60 |  | Заказчик принял документацию. Пользователи ознакомлены с документацией | 0d | 2010-10-05 | 2010-10-05 | 59 |  | 0d |  |
| 61 | 6 | **Миграция пользователей и настройка клиентских мест** | 58d | 2010-07-16 | 2010-10-05 |  |  | 0d |  |
| 62 |  | Подготовить check-list выполнения миграции пользователей | 5d | 2010-07-16 | 2010-07-22 | 37 |  | 17d |  |
| 63 |  | Проверить check-list. Высказать замечания | 2d | 2010-07-23 | 2010-07-26 | 62 |  | 17d |  |
| 64 |  | Доработать check-list в соответствии с замечаниями | 2d | 2010-07-27 | 2010-07-28 | 63 |  | 17d |  |
| 65 |  | Провести миграцию тестовой группы пользователей | 5d | 2010-08-09 | 2010-08-13 | 64, 46 |  | 10d |  |
| 66 |  | Оценить результаты. Доработать check-list | 2d | 2010-08-16 | 2010-08-17 | 65 |  | 10d |  |
| 67 |  | Разработать список пользователей к миграции с детализацией до компании | 5d | 2010-08-25 | 2010-08-31 | 1 |  | 0d | as late as possible |
| 68 |  | Согласовать график проведения миграции с пользователями | 5d | 2010-09-01 | 2010-09-07 | 67, 66, 87 |  | 0d |  |
| 69 |  | Обеспечить миграцию топ-менеджеров, УК | 5d | 2010-09-08 | 2010-09-14 | 68 |  | 0d |  |
| 70 |  | Подписать акт сдачи-приемки миграции топ-менеджеров и сотрудников УК | 0d | 2010-09-14 | 2010-09-14 | 69 |  | 0d |  |

| ID | WBS | Task | Duration | Start | Finish | Predecessors | Complete | Total float |
| --- | --- | --- | --- | --- | --- | --- | --- | --- |
| 71 |  | Обеспечить миграцию пользователей компании А | 5d | 2010-09-15 | 2010-09-21 | 70 |  | 0d |
| 72 |  | Подписать акт сдачи-приемки миграции А | 0d | 2010-09-21 | 2010-09-21 | 71 |  | 0d |
| 73 |  | Обеспечить миграцию пользователей компании Б | 5d | 2010-09-22 | 2010-09-28 | 72 |  | 0d |
| 74 |  | Подписать акт сдачи-приемки миграции Б | 0d | 2010-09-28 | 2010-09-28 | 73 |  | 0d |
| 75 |  | Обеспечить миграцию пользователей компании В | 5d | 2010-09-29 | 2010-10-05 | 74 |  | 0d |
| 76 |  | Подписать акт сдачи-приемки миграции В | 0d | 2010-10-05 | 2010-10-05 | 75 |  | 0d |
| 77 |  | Обеспечить миграцию пользователей компании Г | 5d | 2010-09-08 | 2010-09-14 | 68 |  | 15d |
| 78 |  | Подписать акт сдачи-приемки миграции Г | 0d | 2010-09-14 | 2010-09-14 | 77 |  | 15d |
| 79 |  | Обеспечить миграцию пользователей филиалов | 10d | 2010-09-08 | 2010-09-21 | 68 |  | 10d |
| 80 |  | Подписать акт сдачи-приемки миграции филиалов | 0d | 2010-09-21 | 2010-09-21 | 79 |  | 10d |
| 81 |  | Миграция пользователей и настройка клиентских мест завершена | 0d | 2010-10-05 | 2010-10-05 | 80, 78, 76 |  | 0d |
| 82 | 7 | **Оборудование** | 59d | 2010-05-10 A | 2010-07-29 |  | 43% | 23d |
| 83 |  | Подать заявку на приобретение оборудования | 5d | 2010-05-10 A | 2010-05-14 A | 1 | 100% |  |
| 84 |  | Закупить оборудование в соответствии с Заявкой | 1d | 2010-05-17 A | 2010-05-17 A | 83 | 100% |  |
| 85 |  | Установить оборудование | 3d | 2010-07-20 | 2010-07-22 | 84FS+45d |  | 23d |
| 86 |  | Настроить и проверить работоспособность оборудование | 5d | 2010-07-23 | 2010-07-29 | 85 |  | 23d |
| 87 |  | Оборудование приобретено, настроено и проверено | 0d | 2010-07-29 | 2010-07-29 | 86 |  | 23d |

## Version 2 (data date 2010-07-12, saved 2012-04-28, file Внедрение Exchange (только СДР).mpp)

Last finish 2010-10-05 → 2010-05-21 (-137d). Complete tasks 18 → 0.

Changed:

| ID | Task | Start | Finish | Duration | Complete | Total float | Predecessors | Other |
| --- | --- | --- | --- | --- | --- | --- | --- | --- |
| 1 | Начало проекта | 2010-05-10 A → 2010-04-26 (-14d) | 2010-05-10 A → 2010-04-26 (-14d) |  | 100% → 0% | none → 20d |  | constraint start no earlier than 2010-05-10 → none; baseline start 2010-05-10 → none; baseline finish 2010-05-10 → none |
| 2 | Проект завершен | 2010-10-05 → 2010-04-26 (-162d) | 2010-10-05 → 2010-04-26 (-162d) |  |  | 0d → 20d | 60, 81, 8, 16, 21, 46, 87, 31 → none | baseline start 2010-10-04 → none; baseline finish 2010-10-04 → none |
| 3 | **Обученные пользователи** | 2010-05-10 A → 2010-04-23 (-17d) | 2010-08-17 → 2010-05-07 (-102d) | 72d → 11d | 51% → 0% | 35d → 10d |  | baseline start 2010-05-10 → none; baseline finish 2010-08-24 → none |
| 4 | **Подготовить тренеров** | 2010-05-10 A → 2010-04-26 (-14d) | 2010-05-25 A → 2010-05-07 (-18d) | 12d → 10d | 100% → 0% | none → 10d |  | baseline start 2010-05-10 → none; baseline finish 2010-05-25 → none |
| 5 | Согласовать программу обучения тренеров с Заказчиком | 2010-05-10 A → 2010-04-26 (-14d) | 2010-05-11 A → 2010-04-27 (-14d) |  | 100% → 0% | none → 18d | 1 → none | resources Руководитель проекта; Заказчик проекта → none; baseline start 2010-05-10 → none; baseline finish 2010-05-11 → none |
| 6 | Подписать договор на обучение тренеров | 2010-05-10 A → 2010-04-26 (-14d) | 2010-05-11 A → 2010-04-27 (-14d) |  | 100% → 0% | none → 18d | 1 → none | resources Руководитель проекта; Подрядчик по обучению → none; baseline start 2010-05-10 → none; baseline finish 2010-05-11 → none |
| 7 | Пройти обучение для тренеров | 2010-05-12 A → 2010-04-26 (-16d) | 2010-05-25 A → 2010-05-07 (-18d) |  | 100% → 0% | none → 10d | 5, 6 → none | resources Подрядчик по обучению; HR #2; HR #1; Заказчик проекта; HR #0; HR #3 → none; baseline start 2010-05-12 → none; baseline finish 2010-05-25 → none |
| 8 | Тренеры прошли обучение по работе с Системой | 2010-05-25 A → 2010-04-26 (-29d) | 2010-05-25 A → 2010-04-26 (-29d) |  | 100% → 0% | none → 20d | 7 → none | baseline start 2010-05-25 → none; baseline finish 2010-05-25 → none |
| 9 | **Обучить топ-менеджеров** | 2010-05-19 A → 2010-04-26 (-23d) | 2010-07-08 A → 2010-05-07 (-62d) | 37d → 10d | 100% → 0% | none → 10d |  | baseline start 2010-05-19 → none; baseline finish 2010-06-29 → none |
| 10 | Согласовать программу обучения топ-менеджеров с Заказчиком | 2010-05-19 A → 2010-04-26 (-23d) | 2010-05-25 A → 2010-04-30 (-25d) |  | 100% → 0% | none → 15d | 1 → none | constraint as late as possible → none; resources Руководитель проекта; Заказчик проекта → none; baseline start 2010-05-19 → none; baseline finish 2010-05-25 → none |
| 11 | Подготовить раздаточные материалы для обучения топ-менеджеров | 2010-05-26 A → 2010-04-26 (-30d) | 2010-06-08 A → 2010-05-07 (-32d) |  | 100% → 0% | none → 10d | 10, 8 → none | resources Руководитель проекта → none; baseline start 2010-05-26 → none; baseline finish 2010-06-08 → none |
| 12 | Согласовать график проведения обучения с топ-менеджерами | 2010-05-26 A → 2010-04-26 (-30d) | 2010-06-01 A → 2010-04-30 (-32d) |  | 100% → 0% | none → 15d | 8 → none | resources Топ-менеджеры → none; baseline start 2010-05-26 → none; baseline finish 2010-06-01 → none |
| 13 | Провести обучение топ-менеджеров (группа 1) | 2010-06-09 A → 2010-04-26 (-44d) | 2010-06-11 A → 2010-04-28 (-44d) |  | 100% → 0% | none → 17d | 12, 11 → none | resources HR #1 → none; baseline start 2010-06-09 → none; baseline finish 2010-06-15 → none |
| 14 | Провести обучение топ-менеджеров (группа 2) | 2010-06-14 A → 2010-04-26 (-49d) | 2010-06-18 A → 2010-04-30 (-49d) |  | 100% → 0% | none → 15d | 13 → none | resources HR #2 → none; baseline start 2010-06-16 → none; baseline finish 2010-06-22 → none |
| 15 | Провести обучение топ-менеджеров (группа 3) | 2010-07-08 A → 2010-04-26 (-73d) | 2010-07-08 A → 2010-04-26 (-73d) |  | 100% → 0% | none → 19d | 14 → none | resources HR #3 → none; baseline start 2010-06-23 → none; baseline finish 2010-06-29 → none |
| 16 | Топ-менеджеры прошли обучение | 2010-07-08 A → 2010-04-26 (-73d) | 2010-07-08 A → 2010-04-26 (-73d) |  | 100% → 0% | none → 20d | 15 → none | baseline start 2010-06-29 → none; baseline finish 2010-06-29 → none |
| 17 | **Обучить специалистов ИТ** | 2010-08-02 → 2010-04-26 (-98d) | 2010-08-17 → 2010-05-07 (-102d) | 12d → 10d |  | 35d → 10d |  | baseline start 2010-06-03 → none; baseline finish 2010-06-18 → none |
| 18 | Согласовать программу обучения ИТ специалистов с Заказчиком | 2010-08-02 → 2010-04-26 (-98d) | 2010-08-03 → 2010-04-27 (-98d) |  |  | 35d → 18d | 1 → none | constraint start no earlier than 2010-08-02 → none; resources Руководитель проекта; Заказчик проекта → none; baseline start 2010-06-03 → none; baseline finish 2010-06-04 → none |
| 19 | Подписать договор на обучение ИТ специалистов | 2010-08-02 → 2010-04-26 (-98d) | 2010-08-03 → 2010-04-27 (-98d) |  |  | 35d → 18d | 1 → none | constraint start no earlier than 2010-08-02 → none; resources Руководитель проекта; Подрядчик по обучению → none |
| 20 | Пройти обучение для ИТ-специалистов | 2010-08-04 → 2010-04-26 (-100d) | 2010-08-17 → 2010-05-07 (-102d) |  |  | 35d → 10d | 19, 18 → none | resources Подрядчик по обучению; Администратор Exchange → none; baseline start 2010-06-07 → none; baseline finish 2010-06-18 → none |
| 21 | ИТ-специалисты прошли обучение | 2010-08-17 → 2010-04-26 (-113d) | 2010-08-17 → 2010-04-26 (-113d) |  |  | 35d → 20d | 20 → none | baseline start 2010-06-18 → none; baseline finish 2010-06-18 → none |
| 22 | **Обучить менеджеров среднего звена** | 2010-07-09 → 2010-04-23 (-77d) | 2010-08-11 → 2010-04-30 (-103d) | 24d → 6d |  | 39d → 15d |  | baseline start 2010-06-30 → none; baseline finish 2010-08-24 → none |
| 23 | Согласовать список менеджеров среднего звена к обучению с разбиением на группы | 2010-07-09 → 2010-04-26 (-74d) | 2010-07-14 → 2010-04-29 (-76d) |  |  | 39d → 16d | 16 → none | resources Руководитель проекта; Заказчик проекта → none; baseline start 2010-06-30 → none; baseline finish 2010-07-06 → none |
| 24 | Согласовать график проведения обучения с менджерами среднего звена | 2010-07-09 → 2010-04-26 (-74d) | 2010-07-14 → 2010-04-29 (-76d) |  |  | 39d → 16d | 16 → none | resources Заказчик проекта → none; baseline start 2010-06-30 → none; baseline finish 2010-07-06 → none |
| 25 | Провести обучение менеджеров среднего звена (группа 1) | 2010-07-15 → 2010-04-23 (-83d) | 2010-07-16 → 2010-04-26 (-81d) |  |  | 39d → 19d | 24, 23 → none | constraint start no earlier than 2010-07-12 → finish no earlier than 2010-04-26; resources HR #1 → none; baseline start 2010-07-07 → none; baseline finish 2010-07-13 → none |
| 26 | Провести обучение менеджеров среднего звена (группа 2) | 2010-07-19 → 2010-04-26 (-84d) | 2010-07-22 → 2010-04-29 (-84d) |  |  | 39d → 16d | 25 → none | resources HR #2 → none; baseline start 2010-07-14 → none; baseline finish 2010-07-20 → none |
| 27 | Провести обучение менеджеров среднего звена (группа 3) | 2010-07-23 → 2010-04-26 (-88d) | 2010-07-28 → 2010-04-29 (-90d) |  |  | 39d → 16d | 26 → none | resources HR #3 → none; baseline start 2010-07-21 → none; baseline finish 2010-07-27 → none |
| 28 | Провести обучение менеджеров среднего звена (группа 4) | 2010-07-29 → 2010-04-26 (-94d) | 2010-08-02 → 2010-04-28 (-96d) |  |  | 39d → 17d | 27 → none | resources HR #1 → none; baseline start 2010-07-28 → none; baseline finish 2010-08-03 → none |
| 29 | Провести обучение менеджеров среднего звена (группа 5) | 2010-08-03 → 2010-04-26 (-99d) | 2010-08-04 → 2010-04-27 (-99d) |  |  | 39d → 18d | 28 → none | resources HR #2 → none; baseline start 2010-08-04 → none; baseline finish 2010-08-10 → none |
| 30 | Оценить результаты обучения менеджеров среднего звена | 2010-08-05 → 2010-04-26 (-101d) | 2010-08-11 → 2010-04-30 (-103d) |  |  | 39d → 15d | 29 → none | resources Заказчик проекта → none; baseline start 2010-08-11 → none; baseline finish 2010-08-24 → none |
| 31 | Менеджеры среднего звена прошли обучение | 2010-08-11 → 2010-04-26 (-107d) | 2010-08-11 → 2010-04-26 (-107d) |  |  | 39d → 20d | 30 → none | baseline start 2010-08-24 → none; baseline finish 2010-08-24 → none |
| 32 | **Настроенная Система** | 2010-07-09 A → 2010-04-26 (-74d) | 2010-08-06 → 2010-05-07 (-91d) | 21d → 10d | 16% → 0% | 0d → 10d |  | baseline start 2010-06-16 → none; baseline finish 2010-08-05 → none |
| 33 | **Подготовить требования к Системе** | 2010-07-09 A → 2010-04-26 (-74d) | 2010-07-15 A → 2010-04-28 (-78d) | 5d → 3d | 100% → 0% | none → 17d |  | baseline start 2010-06-16 → none; baseline finish 2010-07-14 → none |
| 34 | Подготовить требования к настройке Системы. Направить на согласование | 2010-07-09 A → 2010-04-26 (-74d) | 2010-07-12 A → 2010-04-27 (-76d) |  | 100% → 0% | none → 18d | 16 → none | resources Руководитель проекта → none; baseline start 2010-06-30 → none; baseline finish 2010-07-06 → none |
| 35 | Согласовать требования к настройке Системы. Высказать замечания | 2010-07-13 A → 2010-04-26 (-78d) | 2010-07-15 A → 2010-04-28 (-78d) |  | 100% → 0% | none → 17d | 34 → none | resources Заказчик проекта → none; baseline start 2010-07-07 → none; baseline finish 2010-07-08 → none |
| 36 | Доработать требования к настройке Системы согласно замечаниям | 2010-07-14 A → 2010-04-26 (-79d) | 2010-07-15 A → 2010-04-26 (-80d) |  | 100% → 0% | none → 19d | 35 → none | resources Руководитель проекта → none; baseline start 2010-07-09 → none; baseline finish 2010-07-13 → none |
| 37 | Подписать требования к настройке Системы | 2010-07-15 A → 2010-04-26 (-80d) | 2010-07-15 A → 2010-04-26 (-80d) |  | 100% → 0% | none → 20d | 36 → none | resources Заказчик проекта → none; baseline start 2010-07-14 → none; baseline finish 2010-07-14 → none |
| 38 | **Настроить серверную часть** | 2010-07-16 → 2010-04-26 (-81d) | 2010-08-06 → 2010-05-07 (-91d) | 16d → 10d |  | 0d → 10d |  | baseline start 2010-07-15 → none; baseline finish 2010-08-05 → none |
| 39 | Настроить серверную часть Календарь | 2010-07-16 → 2010-04-26 (-81d) | 2010-07-21 → 2010-04-29 (-83d) |  |  | 0d → 16d | 37 → none | resources Администратор Exchange → none; baseline start 2010-07-15 → none; baseline finish 2010-07-20 → none |
| 40 | Настроить серверную часть Почта | 2010-07-22 → 2010-04-26 (-87d) | 2010-07-27 → 2010-04-29 (-89d) |  |  | 0d → 16d | 39 → none | resources Администратор Exchange → none; baseline start 2010-07-21 → none; baseline finish 2010-07-26 → none |
| 41 | Настроить серверную часть Задачи | 2010-07-28 → 2010-04-26 (-93d) | 2010-08-02 → 2010-04-29 (-95d) |  |  | 0d → 16d | 40 → none | resources Администратор Exchange → none; baseline start 2010-07-27 → none; baseline finish 2010-07-30 → none |
| 42 | Настроить серверную часть Контакты | 2010-08-03 → 2010-04-26 (-99d) | 2010-08-06 → 2010-04-29 (-99d) |  |  | 0d → 16d | 41 → none | resources Администратор Exchange → none; baseline start 2010-08-02 → none; baseline finish 2010-08-05 → none |
| 43 | Настроить серверную часть Синхронизация и удаленный доступ | 2010-07-16 → 2010-04-26 (-81d) | 2010-07-29 → 2010-05-07 (-83d) |  |  | 0d → 10d | 37 → none | resources Администратор Exchange → none; baseline start 2010-07-15 → none; baseline finish 2010-07-28 → none |
| 44 | Настроить серверную часть Технические настройки | 2010-07-30 → 2010-04-26 (-95d) | 2010-08-04 → 2010-04-29 (-97d) |  |  | 0d → 16d | 43 → none | resources Администратор Exchange → none; baseline start 2010-07-29 → none; baseline finish 2010-08-03 → none |
| 45 | Проверить работоспособность настроенных функций | 2010-08-05 → 2010-04-26 (-101d) | 2010-08-06 → 2010-04-27 (-101d) |  |  | 0d → 18d | 44 → none | resources Руководитель проекта; Заказчик проекта → none; baseline start 2010-08-04 → none; baseline finish 2010-08-05 → none |
| 46 | Серверная часть настроена в соответствии с требованиями | 2010-08-06 → 2010-04-26 (-102d) | 2010-08-06 → 2010-04-26 (-102d) |  |  | 0d → 20d | 45, 42 → none | baseline start 2010-08-05 → none; baseline finish 2010-08-05 → none |
| 47 | **Документация к Системе** | 2010-07-19 → 2010-04-26 (-84d) | 2010-10-05 → 2010-05-21 (-137d) | 57d → 20d |  |  |  | baseline start 2010-07-16 → none; baseline finish 2010-10-04 → none |
| 48 | Описать настройки Системы (адреса, пароли и явки) | 2010-08-09 → 2010-04-26 (-105d) | 2010-08-13 → 2010-04-30 (-105d) |  |  | 0d → 15d | 46 → none | resources Руководитель проекта → none; baseline start 2010-08-06 → none; baseline finish 2010-08-12 → none |
| 49 | Предоставить формат описания пользовательской документации | 2010-07-19 → 2010-05-17 (-63d) | 2010-07-23 → 2010-05-21 (-63d) |  |  |  | 1 → none | resources Заказчик проекта → none; baseline start 2010-07-16 → none; baseline finish 2010-07-22 → none |
| 50 | Разработать документацию к Системе. Календарь | 2010-07-26 → 2010-04-26 (-91d) | 2010-07-30 → 2010-04-30 (-91d) |  |  | 0d → 15d | 39, 49 → none | resources Руководитель проекта → none; baseline start 2010-07-23 → none; baseline finish 2010-07-29 → none |
| 51 | Разработать документацию к Системе. Почта | 2010-08-02 → 2010-04-26 (-98d) | 2010-08-06 → 2010-04-30 (-98d) |  |  | 0d → 15d | 50, 40 → none | resources Руководитель проекта → none; baseline start 2010-07-30 → none; baseline finish 2010-08-05 → none |
| 52 | Разработать документацию к Системе. Задачи | 2010-08-09 → 2010-04-26 (-105d) | 2010-08-13 → 2010-04-30 (-105d) |  |  | 0d → 15d | 51, 41 → none | resources Руководитель проекта → none; baseline start 2010-08-06 → none; baseline finish 2010-08-12 → none |
| 53 | Разработать документацию к Системе. Контакты | 2010-08-16 → 2010-04-26 (-112d) | 2010-08-20 → 2010-04-30 (-112d) |  |  | 0d → 15d | 52, 42 → none | resources Руководитель проекта → none; baseline start 2010-08-13 → none; baseline finish 2010-08-19 → none |
| 54 | Разработать документацию к Системе. Синхронизация и удаленный доступ | 2010-07-30 → 2010-04-26 (-95d) | 2010-08-05 → 2010-04-30 (-97d) |  |  | 11d → 15d | 43 → none | resources Руководитель проекта → none; baseline start 2010-07-29 → none; baseline finish 2010-08-04 → none |
| 55 | Разработать документацию к Системе. Администрирование и поддержка Системы | 2010-08-16 → 2010-04-26 (-112d) | 2010-08-20 → 2010-04-30 (-112d) |  |  | 0d → 15d | 48, 44 → none | resources Руководитель проекта → none; baseline start 2010-08-13 → none; baseline finish 2010-08-19 → none |
| 56 | Подписать Акт сдачи-приемки документации к Системе | 2010-08-23 → 2010-04-26 (-119d) | 2010-08-24 → 2010-04-27 (-119d) |  |  | 0d → 18d | 50, 51, 52, 53, 54, 55 → none | resources Руководитель проекта; Заказчик проекта → none; baseline start 2010-08-20 → none; baseline finish 2010-08-23 → none |
| 57 | Резерв времени на разработку документации к Системе | 2010-08-25 → 2010-04-26 (-121d) | 2010-09-21 → 2010-05-21 (-123d) |  |  |  | 56 → none | baseline start 2010-08-24 → none; baseline finish 2010-09-20 → none |
| 58 | Утвердить документацию к Системе на СД | 2010-09-22 → 2010-04-26 (-149d) | 2010-09-28 → 2010-04-30 (-151d) |  |  | 0d → 15d | 57 → none | resources Заказчик проекта → none; baseline start 2010-09-21 → none; baseline finish 2010-09-27 → none |
| 59 | Ознакомить пользователей с документацией к Системе | 2010-09-29 → 2010-04-26 (-156d) | 2010-10-05 → 2010-04-30 (-158d) |  |  | 0d → 15d | 58 → none | resources HR #2; HR #3; HR #1; HR #0 → none; baseline start 2010-09-28 → none; baseline finish 2010-10-04 → none |
| 60 | Заказчик принял документацию. Пользователи ознакомлены с документацией | 2010-10-05 → 2010-04-26 (-162d) | 2010-10-05 → 2010-04-26 (-162d) |  |  | 0d → 20d | 59 → none | baseline start 2010-10-04 → none; baseline finish 2010-10-04 → none |
| 61 | **Миграция пользователей и настройка клиентских мест** | 2010-07-16 → 2010-04-26 (-81d) | 2010-10-05 → 2010-05-21 (-137d) | 58d → 20d |  |  |  | baseline start 2010-07-15 → none; baseline finish 2010-10-04 → none |
| 62 | Подготовить check-list выполнения миграции пользователей | 2010-07-16 → 2010-04-26 (-81d) | 2010-07-22 → 2010-04-30 (-83d) |  |  | 17d → 15d | 37 → none | resources Руководитель проекта → none; baseline start 2010-07-15 → none; baseline finish 2010-07-21 → none |
| 63 | Проверить check-list. Высказать замечания | 2010-07-23 → 2010-04-26 (-88d) | 2010-07-26 → 2010-04-27 (-90d) |  |  | 17d → 18d | 62 → none | resources Заказчик проекта → none; baseline start 2010-07-22 → none; baseline finish 2010-07-23 → none |
| 64 | Доработать check-list в соответствии с замечаниями | 2010-07-27 → 2010-04-26 (-92d) | 2010-07-28 → 2010-04-27 (-92d) |  |  | 17d → 18d | 63 → none | resources Руководитель проекта → none; baseline start 2010-07-26 → none; baseline finish 2010-07-27 → none |
| 65 | Провести миграцию тестовой группы пользователей | 2010-08-09 → 2010-04-26 (-105d) | 2010-08-13 → 2010-04-30 (-105d) |  |  | 10d → 15d | 64, 46 → none | resources Администратор Exchange → none; baseline start 2010-08-06 → none; baseline finish 2010-08-12 → none |
| 66 | Оценить результаты. Доработать check-list | 2010-08-16 → 2010-04-26 (-112d) | 2010-08-17 → 2010-04-27 (-112d) |  |  | 10d → 18d | 65 → none | resources Руководитель проекта → none; baseline start 2010-08-13 → none; baseline finish 2010-08-16 → none |
| 67 | Разработать список пользователей к миграции с детализацией до компании | 2010-08-25 → 2010-05-17 (-100d) | 2010-08-31 → 2010-05-21 (-102d) |  |  |  | 1 → none | resources Руководитель проекта → none; baseline start 2010-08-24 → none; baseline finish 2010-08-30 → none |
| 68 | Согласовать график проведения миграции с пользователями | 2010-09-01 → 2010-04-26 (-128d) | 2010-09-07 → 2010-04-30 (-130d) |  |  | 0d → 15d | 67, 66, 87 → none | resources Топ-менеджеры → none; baseline start 2010-08-31 → none; baseline finish 2010-09-06 → none |
| 69 | Обеспечить миграцию топ-менеджеров, УК | 2010-09-08 → 2010-04-26 (-135d) | 2010-09-14 → 2010-04-30 (-137d) |  |  | 0d → 15d | 68 → none | resources Администратор Exchange → none; baseline start 2010-09-07 → none; baseline finish 2010-09-13 → none |
| 70 | Подписать акт сдачи-приемки миграции топ-менеджеров и сотрудников УК | 2010-09-14 → 2010-04-26 (-141d) | 2010-09-14 → 2010-04-26 (-141d) |  |  | 0d → 20d | 69 → none | resources Руководитель проекта; Заказчик проекта → none; baseline start 2010-09-13 → none; baseline finish 2010-09-13 → none |

| ID | Task | Start | Finish | Duration | Complete | Total float | Predecessors | Other |
| --- | --- | --- | --- | --- | --- | --- | --- | --- |
| 71 | Обеспечить миграцию пользователей компании А | 2010-09-15 → 2010-04-26 (-142d) | 2010-09-21 → 2010-04-30 (-144d) |  |  | 0d → 15d | 70 → none | resources Администратор Exchange → none; baseline start 2010-09-14 → none; baseline finish 2010-09-20 → none |
| 72 | Подписать акт сдачи-приемки миграции А | 2010-09-21 → 2010-04-26 (-148d) | 2010-09-21 → 2010-04-26 (-148d) |  |  | 0d → 20d | 71 → none | resources Руководитель проекта; Заказчик проекта → none; baseline start 2010-09-20 → none; baseline finish 2010-09-20 → none |
| 73 | Обеспечить миграцию пользователей компании Б | 2010-09-22 → 2010-04-26 (-149d) | 2010-09-28 → 2010-04-30 (-151d) |  |  | 0d → 15d | 72 → none | resources Администратор Exchange → none; baseline start 2010-09-21 → none; baseline finish 2010-09-27 → none |
| 74 | Подписать акт сдачи-приемки миграции Б | 2010-09-28 → 2010-04-26 (-155d) | 2010-09-28 → 2010-04-26 (-155d) |  |  | 0d → 20d | 73 → none | resources Руководитель проекта; Заказчик проекта → none; baseline start 2010-09-27 → none; baseline finish 2010-09-27 → none |
| 75 | Обеспечить миграцию пользователей компании В | 2010-09-29 → 2010-04-26 (-156d) | 2010-10-05 → 2010-04-30 (-158d) |  |  | 0d → 15d | 74 → none | resources Администратор Exchange → none; baseline start 2010-09-28 → none; baseline finish 2010-10-04 → none |
| 76 | Подписать акт сдачи-приемки миграции В | 2010-10-05 → 2010-04-26 (-162d) | 2010-10-05 → 2010-04-26 (-162d) |  |  | 0d → 20d | 75 → none | resources Руководитель проекта; Заказчик проекта → none; baseline start 2010-10-04 → none; baseline finish 2010-10-04 → none |
| 77 | Обеспечить миграцию пользователей компании Г | 2010-09-08 → 2010-04-26 (-135d) | 2010-09-14 → 2010-04-30 (-137d) |  |  |  | 68 → none | resources Администратор Exchange → none; baseline start 2010-09-07 → none; baseline finish 2010-09-13 → none |
| 78 | Подписать акт сдачи-приемки миграции Г | 2010-09-14 → 2010-04-26 (-141d) | 2010-09-14 → 2010-04-26 (-141d) |  |  | 15d → 20d | 77 → none | resources Руководитель проекта; Заказчик проекта → none; baseline start 2010-09-13 → none; baseline finish 2010-09-13 → none |
| 79 | Обеспечить миграцию пользователей филиалов | 2010-09-08 → 2010-04-26 (-135d) | 2010-09-21 → 2010-05-07 (-137d) |  |  |  | 68 → none | resources Администратор Exchange → none; baseline start 2010-09-07 → none; baseline finish 2010-09-20 → none |
| 80 | Подписать акт сдачи-приемки миграции филиалов | 2010-09-21 → 2010-04-26 (-148d) | 2010-09-21 → 2010-04-26 (-148d) |  |  | 10d → 20d | 79 → none | resources Руководитель проекта; Заказчик проекта → none; baseline start 2010-09-20 → none; baseline finish 2010-09-20 → none |
| 81 | Миграция пользователей и настройка клиентских мест завершена | 2010-10-05 → 2010-04-26 (-162d) | 2010-10-05 → 2010-04-26 (-162d) |  |  | 0d → 20d | 80, 78, 76 → none | baseline start 2010-10-04 → none; baseline finish 2010-10-04 → none |
| 82 | **Оборудование** | 2010-05-10 A → 2010-04-26 (-14d) | 2010-07-29 → 2010-04-30 (-90d) | 59d → 5d | 43% → 0% | 23d → 15d |  | baseline start 2010-05-10 → none; baseline finish 2010-07-29 → none |
| 83 | Подать заявку на приобретение оборудования | 2010-05-10 A → 2010-04-26 (-14d) | 2010-05-14 A → 2010-04-30 (-14d) |  | 100% → 0% | none → 15d | 1 → none | resources Руководитель проекта → none; baseline start 2010-05-10 → none; baseline finish 2010-05-14 → none |
| 84 | Закупить оборудование в соответствии с Заявкой | 2010-05-17 A → 2010-04-26 (-21d) | 2010-05-17 A → 2010-04-26 (-21d) |  | 100% → 0% | none → 19d | 83 → none | resources Закупщик ИТ → none; baseline start 2010-05-17 → none; baseline finish 2010-05-17 → none |
| 85 | Установить оборудование | 2010-07-20 → 2010-04-26 (-85d) | 2010-07-22 → 2010-04-28 (-85d) |  |  | 23d → 17d | 84FS+45d → none | resources Руководитель проекта → none; baseline start 2010-07-20 → none; baseline finish 2010-07-22 → none |
| 86 | Настроить и проверить работоспособность оборудование | 2010-07-23 → 2010-04-26 (-88d) | 2010-07-29 → 2010-04-30 (-90d) |  |  | 23d → 15d | 85 → none | resources Руководитель проекта → none; baseline start 2010-07-23 → none; baseline finish 2010-07-29 → none |
| 87 | Оборудование приобретено, настроено и проверено | 2010-07-29 → 2010-04-26 (-94d) | 2010-07-29 → 2010-04-26 (-94d) |  |  | 23d → 20d | 86 → none | baseline start 2010-07-29 → none; baseline finish 2010-07-29 → none |

## Version 3 (data date 2010-07-12, saved 2012-04-28, file Внедрение Exchange (СДР и ресурсы).mpp)

Last finish 2010-05-21 → 2010-07-13 (+53d).

Changed:

| ID | Task | Start | Finish | Duration | Total float | Other |
| --- | --- | --- | --- | --- | --- | --- |
| 3 | **Обученные пользователи** | 2010-04-23 → 2010-04-26 (+3d) | 2010-05-07 → 2010-07-13 (+67d) | 11d → 57d | 10d → 0d |  |
| 5 | Согласовать программу обучения тренеров с Заказчиком |  |  |  | 18d → 55d | resources none → Руководитель проекта; Заказчик проекта |
| 6 | Подписать договор на обучение тренеров |  |  |  | 18d → 0d | resources none → Руководитель проекта; Подрядчик по обучению |
| 7 | Пройти обучение для тренеров |  |  |  | 10d → 47d | resources none → Подрядчик по обучению; HR #2; HR #1; Заказчик проекта; HR #0; HR #3 |
| 10 | Согласовать программу обучения топ-менеджеров с Заказчиком |  |  |  | 15d → 52d | resources none → Руководитель проекта; Заказчик проекта |
| 11 | Подготовить раздаточные материалы для обучения топ-менеджеров |  |  |  | 10d → 47d | resources none → Руководитель проекта |
| 12 | Согласовать график проведения обучения с топ-менеджерами |  |  |  | 15d → 52d | resources none → Топ-менеджеры |
| 13 | Провести обучение топ-менеджеров (группа 1) |  |  |  | 17d → 54d | resources none → HR #1 |
| 14 | Провести обучение топ-менеджеров (группа 2) |  |  |  | 15d → 52d | resources none → HR #2 |
| 15 | Провести обучение топ-менеджеров (группа 3) |  |  |  | 19d → 56d | resources none → HR #3 |
| 18 | Согласовать программу обучения ИТ специалистов с Заказчиком |  |  |  | 18d → 55d | resources none → Руководитель проекта; Заказчик проекта |
| 19 | Подписать договор на обучение ИТ специалистов |  |  |  | 18d → 55d | resources none → Руководитель проекта; Подрядчик по обучению |
| 20 | Пройти обучение для ИТ-специалистов |  |  |  | 10d → 47d | resources none → Подрядчик по обучению; Администратор Exchange |
| 22 | **Обучить менеджеров среднего звена** | 2010-04-23 → 2010-04-26 (+3d) | 2010-04-30 → 2010-07-13 (+74d) | 6d → 57d | 15d → 0d |  |
| 23 | Согласовать список менеджеров среднего звена к обучению с разбиением на группы |  |  |  | 16d → 53d | resources none → Руководитель проекта; Заказчик проекта |
| 24 | Согласовать график проведения обучения с менджерами среднего звена |  |  |  | 16d → 53d | resources none → Заказчик проекта |
| 25 | Провести обучение менеджеров среднего звена (группа 1) | 2010-04-23 → 2010-07-12 (+80d) | 2010-04-26 → 2010-07-13 (+78d) |  | 19d → 0d | constraint finish no earlier than 2010-04-26 → start no earlier than 2010-07-12; resources none → HR #1 |
| 26 | Провести обучение менеджеров среднего звена (группа 2) |  |  |  | 16d → 53d | resources none → HR #2 |
| 27 | Провести обучение менеджеров среднего звена (группа 3) |  |  |  | 16d → 53d | resources none → HR #3 |
| 28 | Провести обучение менеджеров среднего звена (группа 4) |  |  |  | 17d → 54d | resources none → HR #1 |
| 29 | Провести обучение менеджеров среднего звена (группа 5) |  |  |  | 18d → 55d | resources none → HR #2 |
| 30 | Оценить результаты обучения менеджеров среднего звена |  |  |  | 15d → 52d | resources none → Заказчик проекта |
| 34 | Подготовить требования к настройке Системы. Направить на согласование |  |  |  | 18d → 55d | resources none → Руководитель проекта |
| 35 | Согласовать требования к настройке Системы. Высказать замечания |  |  |  | 17d → 54d | resources none → Заказчик проекта |
| 36 | Доработать требования к настройке Системы согласно замечаниям |  |  |  | 19d → 56d | resources none → Руководитель проекта |
| 37 | Подписать требования к настройке Системы |  |  |  | 20d → 0d | resources none → Заказчик проекта |
| 39 | Настроить серверную часть Календарь |  |  |  | 16d → 53d | resources none → Администратор Exchange |
| 40 | Настроить серверную часть Почта |  |  |  | 16d → 53d | resources none → Администратор Exchange |
| 41 | Настроить серверную часть Задачи |  |  |  | 16d → 53d | resources none → Администратор Exchange |
| 42 | Настроить серверную часть Контакты |  |  |  | 16d → 53d | resources none → Администратор Exchange |
| 43 | Настроить серверную часть Синхронизация и удаленный доступ |  |  |  | 10d → 47d | resources none → Администратор Exchange |
| 44 | Настроить серверную часть Технические настройки |  |  |  | 16d → 53d | resources none → Администратор Exchange |
| 45 | Проверить работоспособность настроенных функций |  |  |  | 18d → 55d | resources none → Руководитель проекта; Заказчик проекта |
| 47 | **Документация к Системе** |  | 2010-05-21 → 2010-07-13 (+53d) | 20d → 57d |  |  |
| 48 | Описать настройки Системы (адреса, пароли и явки) |  |  |  | 15d → 52d | resources none → Руководитель проекта |
| 49 | Предоставить формат описания пользовательской документации | 2010-05-17 → 2010-07-07 (+51d) | 2010-05-21 → 2010-07-13 (+53d) |  |  | resources none → Заказчик проекта |
| 50 | Разработать документацию к Системе. Календарь |  |  |  | 15d → 52d | resources none → Руководитель проекта |
| 51 | Разработать документацию к Системе. Почта |  |  |  | 15d → 52d | resources none → Руководитель проекта |
| 52 | Разработать документацию к Системе. Задачи |  |  |  | 15d → 52d | resources none → Руководитель проекта |
| 53 | Разработать документацию к Системе. Контакты |  |  |  | 15d → 52d | resources none → Руководитель проекта |
| 54 | Разработать документацию к Системе. Синхронизация и удаленный доступ |  |  |  | 15d → 52d | resources none → Руководитель проекта |
| 55 | Разработать документацию к Системе. Администрирование и поддержка Системы |  |  |  | 15d → 52d | resources none → Руководитель проекта |
| 56 | Подписать Акт сдачи-приемки документации к Системе |  |  |  | 18d → 55d | resources none → Руководитель проекта; Заказчик проекта |
| 58 | Утвердить документацию к Системе на СД |  |  |  | 15d → 52d | resources none → Заказчик проекта |
| 59 | Ознакомить пользователей с документацией к Системе |  |  |  | 15d → 52d | resources none → HR #2; HR #3; HR #1; HR #0 |
| 61 | **Миграция пользователей и настройка клиентских мест** |  | 2010-05-21 → 2010-07-13 (+53d) | 20d → 57d |  |  |
| 62 | Подготовить check-list выполнения миграции пользователей |  |  |  | 15d → 52d | resources none → Руководитель проекта |
| 63 | Проверить check-list. Высказать замечания |  |  |  | 18d → 55d | resources none → Заказчик проекта |
| 64 | Доработать check-list в соответствии с замечаниями |  |  |  | 18d → 55d | resources none → Руководитель проекта |
| 65 | Провести миграцию тестовой группы пользователей |  |  |  | 15d → 52d | resources none → Администратор Exchange |
| 66 | Оценить результаты. Доработать check-list |  |  |  | 18d → 55d | resources none → Руководитель проекта |
| 67 | Разработать список пользователей к миграции с детализацией до компании | 2010-05-17 → 2010-07-07 (+51d) | 2010-05-21 → 2010-07-13 (+53d) |  |  | resources none → Руководитель проекта |
| 68 | Согласовать график проведения миграции с пользователями |  |  |  | 15d → 52d | resources none → Топ-менеджеры |
| 69 | Обеспечить миграцию топ-менеджеров, УК |  |  |  | 15d → 52d | resources none → Администратор Exchange |
| 70 | Подписать акт сдачи-приемки миграции топ-менеджеров и сотрудников УК |  |  |  | 20d → 57d | resources none → Руководитель проекта; Заказчик проекта |
| 71 | Обеспечить миграцию пользователей компании А |  |  |  | 15d → 52d | resources none → Администратор Exchange |
| 72 | Подписать акт сдачи-приемки миграции А |  |  |  | 20d → 57d | resources none → Руководитель проекта; Заказчик проекта |
| 73 | Обеспечить миграцию пользователей компании Б |  |  |  | 15d → 52d | resources none → Администратор Exchange |
| 74 | Подписать акт сдачи-приемки миграции Б |  |  |  | 20d → 57d | resources none → Руководитель проекта; Заказчик проекта |
| 75 | Обеспечить миграцию пользователей компании В |  |  |  | 15d → 52d | resources none → Администратор Exchange |
| 76 | Подписать акт сдачи-приемки миграции В |  |  |  | 20d → 57d | resources none → Руководитель проекта; Заказчик проекта |
| 77 | Обеспечить миграцию пользователей компании Г |  |  |  | 15d → 52d | resources none → Администратор Exchange |
| 78 | Подписать акт сдачи-приемки миграции Г |  |  |  | 20d → 57d | resources none → Руководитель проекта; Заказчик проекта |
| 79 | Обеспечить миграцию пользователей филиалов |  |  |  | 10d → 47d | resources none → Администратор Exchange |
| 80 | Подписать акт сдачи-приемки миграции филиалов |  |  |  | 20d → 57d | resources none → Руководитель проекта; Заказчик проекта |
| 83 | Подать заявку на приобретение оборудования |  |  |  | 15d → 52d | resources none → Руководитель проекта |
| 84 | Закупить оборудование в соответствии с Заявкой |  |  |  | 19d → 56d | resources none → Закупщик ИТ |
| 85 | Установить оборудование |  |  |  | 17d → 54d | resources none → Руководитель проекта |
| 86 | Настроить и проверить работоспособность оборудование |  |  |  | 15d → 52d | resources none → Руководитель проекта |

## Version 4 (data date 2010-07-12, saved 2012-04-28, file Внедрение Exchange (структура, ресурсы и связи).mpp)

Last finish 2010-07-13 → 2010-09-03 (+52d).

Changed:

| ID | Task | Start | Finish | Duration | Total float | Predecessors |
| --- | --- | --- | --- | --- | --- | --- |
| 2 | Проект завершен | 2010-04-26 → 2010-09-03 (+130d) | 2010-04-26 → 2010-09-03 (+130d) |  | 57d → 0d | none → 60, 81, 8, 16, 21, 46, 87, 31 |
| 3 | **Обученные пользователи** |  | 2010-07-13 → 2010-08-06 (+24d) | 57d → 75d |  |  |
| 4 | **Подготовить тренеров** |  | 2010-05-07 → 2010-05-11 (+4d) | 10d → 12d |  |  |
| 5 | Согласовать программу обучения тренеров с Заказчиком |  |  |  | 55d → 0d | none → 1 |
| 6 | Подписать договор на обучение тренеров |  |  |  |  | none → 1 |
| 7 | Пройти обучение для тренеров | 2010-04-26 → 2010-04-28 (+2d) | 2010-05-07 → 2010-05-11 (+4d) |  | 47d → 0d | none → 5, 6 |
| 8 | Тренеры прошли обучение по работе с Системой | 2010-04-26 → 2010-05-11 (+15d) | 2010-04-26 → 2010-05-11 (+15d) |  | 57d → 0d | none → 7 |
| 9 | **Обучить топ-менеджеров** |  | 2010-05-07 → 2010-06-07 (+31d) | 10d → 31d | 47d → 0d |  |
| 10 | Согласовать программу обучения топ-менеджеров с Заказчиком |  |  |  | 52d → 7d | none → 1 |
| 11 | Подготовить раздаточные материалы для обучения топ-менеджеров | 2010-04-26 → 2010-05-12 (+16d) | 2010-05-07 → 2010-05-25 (+18d) |  | 47d → 0d | none → 10, 8 |
| 12 | Согласовать график проведения обучения с топ-менеджерами | 2010-04-26 → 2010-05-12 (+16d) | 2010-04-30 → 2010-05-18 (+18d) |  | 52d → 5d | none → 8 |
| 13 | Провести обучение топ-менеджеров (группа 1) | 2010-04-26 → 2010-05-26 (+30d) | 2010-04-28 → 2010-05-28 (+30d) |  | 54d → 0d | none → 12, 11 |
| 14 | Провести обучение топ-менеджеров (группа 2) | 2010-04-26 → 2010-05-31 (+35d) | 2010-04-30 → 2010-06-04 (+35d) |  | 52d → 0d | none → 13 |
| 15 | Провести обучение топ-менеджеров (группа 3) | 2010-04-26 → 2010-06-07 (+42d) | 2010-04-26 → 2010-06-07 (+42d) |  | 56d → 0d | none → 14 |
| 16 | Топ-менеджеры прошли обучение | 2010-04-26 → 2010-06-07 (+42d) | 2010-04-26 → 2010-06-07 (+42d) |  | 57d → 0d | none → 15 |
| 17 | **Обучить специалистов ИТ** |  | 2010-05-07 → 2010-05-11 (+4d) | 10d → 12d | 47d → 83d |  |
| 18 | Согласовать программу обучения ИТ специалистов с Заказчиком |  |  |  | 55d → 83d | none → 1 |
| 19 | Подписать договор на обучение ИТ специалистов |  |  |  | 55d → 83d | none → 1 |
| 20 | Пройти обучение для ИТ-специалистов | 2010-04-26 → 2010-04-28 (+2d) | 2010-05-07 → 2010-05-11 (+4d) |  | 47d → 83d | none → 19, 18 |
| 21 | ИТ-специалисты прошли обучение | 2010-04-26 → 2010-05-11 (+15d) | 2010-04-26 → 2010-05-11 (+15d) |  | 57d → 83d | none → 20 |
| 22 | **Обучить менеджеров среднего звена** | 2010-04-26 → 2010-06-08 (+43d) | 2010-07-13 → 2010-08-06 (+24d) | 57d → 44d | 0d → 20d |  |
| 23 | Согласовать список менеджеров среднего звена к обучению с разбиением на группы | 2010-04-26 → 2010-06-08 (+43d) | 2010-04-29 → 2010-06-11 (+43d) |  | 53d → 40d | none → 16 |
| 24 | Согласовать график проведения обучения с менджерами среднего звена | 2010-04-26 → 2010-06-08 (+43d) | 2010-04-29 → 2010-06-11 (+43d) |  | 53d → 40d | none → 16 |
| 25 | Провести обучение менеджеров среднего звена (группа 1) |  |  |  | 0d → 20d | none → 24, 23 |
| 26 | Провести обучение менеджеров среднего звена (группа 2) | 2010-04-26 → 2010-07-14 (+79d) | 2010-04-29 → 2010-07-19 (+81d) |  | 53d → 20d | none → 25 |
| 27 | Провести обучение менеджеров среднего звена (группа 3) | 2010-04-26 → 2010-07-20 (+85d) | 2010-04-29 → 2010-07-23 (+85d) |  | 53d → 20d | none → 26 |
| 28 | Провести обучение менеджеров среднего звена (группа 4) | 2010-04-26 → 2010-07-26 (+91d) | 2010-04-28 → 2010-07-28 (+91d) |  | 54d → 20d | none → 27 |
| 29 | Провести обучение менеджеров среднего звена (группа 5) | 2010-04-26 → 2010-07-29 (+94d) | 2010-04-27 → 2010-07-30 (+94d) |  | 55d → 20d | none → 28 |
| 30 | Оценить результаты обучения менеджеров среднего звена | 2010-04-26 → 2010-08-02 (+98d) | 2010-04-30 → 2010-08-06 (+98d) |  | 52d → 20d | none → 29 |
| 31 | Менеджеры среднего звена прошли обучение | 2010-04-26 → 2010-08-06 (+102d) | 2010-04-26 → 2010-08-06 (+102d) |  | 57d → 20d | none → 30 |
| 32 | **Настроенная Система** | 2010-04-26 → 2010-06-08 (+43d) | 2010-05-07 → 2010-07-07 (+61d) | 10d → 22d |  |  |
| 33 | **Подготовить требования к Системе** | 2010-04-26 → 2010-06-08 (+43d) | 2010-04-28 → 2010-06-15 (+48d) | 3d → 6d |  |  |
| 34 | Подготовить требования к настройке Системы. Направить на согласование | 2010-04-26 → 2010-06-08 (+43d) | 2010-04-27 → 2010-06-09 (+43d) |  | 55d → 0d | none → 16 |
| 35 | Согласовать требования к настройке Системы. Высказать замечания | 2010-04-26 → 2010-06-10 (+45d) | 2010-04-28 → 2010-06-14 (+47d) |  | 54d → 0d | none → 34 |
| 36 | Доработать требования к настройке Системы согласно замечаниям | 2010-04-26 → 2010-06-15 (+50d) | 2010-04-26 → 2010-06-15 (+50d) |  | 56d → 0d | none → 35 |
| 37 | Подписать требования к настройке Системы | 2010-04-26 → 2010-06-15 (+50d) | 2010-04-26 → 2010-06-15 (+50d) |  |  | none → 36 |
| 38 | **Настроить серверную часть** | 2010-04-26 → 2010-06-16 (+51d) | 2010-05-07 → 2010-07-07 (+61d) | 10d → 16d | 47d → 0d |  |
| 39 | Настроить серверную часть Календарь | 2010-04-26 → 2010-06-16 (+51d) | 2010-04-29 → 2010-06-21 (+53d) |  | 53d → 0d | none → 37 |
| 40 | Настроить серверную часть Почта | 2010-04-26 → 2010-06-22 (+57d) | 2010-04-29 → 2010-06-25 (+57d) |  | 53d → 0d | none → 39 |
| 41 | Настроить серверную часть Задачи | 2010-04-26 → 2010-06-28 (+63d) | 2010-04-29 → 2010-07-01 (+63d) |  | 53d → 0d | none → 40 |
| 42 | Настроить серверную часть Контакты | 2010-04-26 → 2010-07-02 (+67d) | 2010-04-29 → 2010-07-07 (+69d) |  | 53d → 0d | none → 41 |
| 43 | Настроить серверную часть Синхронизация и удаленный доступ | 2010-04-26 → 2010-06-16 (+51d) | 2010-05-07 → 2010-06-29 (+53d) |  | 47d → 0d | none → 37 |
| 44 | Настроить серверную часть Технические настройки | 2010-04-26 → 2010-06-30 (+65d) | 2010-04-29 → 2010-07-05 (+67d) |  | 53d → 0d | none → 43 |
| 45 | Проверить работоспособность настроенных функций | 2010-04-26 → 2010-07-06 (+71d) | 2010-04-27 → 2010-07-07 (+71d) |  | 55d → 0d | none → 44 |
| 46 | Серверная часть настроена в соответствии с требованиями | 2010-04-26 → 2010-07-07 (+72d) | 2010-04-26 → 2010-07-07 (+72d) |  | 57d → 0d | none → 45, 42 |
| 47 | **Документация к Системе** | 2010-04-26 → 2010-06-17 (+52d) | 2010-07-13 → 2010-09-03 (+52d) |  |  |  |
| 48 | Описать настройки Системы (адреса, пароли и явки) | 2010-04-26 → 2010-07-08 (+73d) | 2010-04-30 → 2010-07-14 (+75d) |  | 52d → 0d | none → 46 |
| 49 | Предоставить формат описания пользовательской документации | 2010-07-07 → 2010-06-17 (-20d) | 2010-07-13 → 2010-06-23 (-20d) |  |  | none → 1 |
| 50 | Разработать документацию к Системе. Календарь | 2010-04-26 → 2010-06-24 (+59d) | 2010-04-30 → 2010-06-30 (+61d) |  | 52d → 0d | none → 39, 49 |
| 51 | Разработать документацию к Системе. Почта | 2010-04-26 → 2010-07-01 (+66d) | 2010-04-30 → 2010-07-07 (+68d) |  | 52d → 0d | none → 50, 40 |
| 52 | Разработать документацию к Системе. Задачи | 2010-04-26 → 2010-07-08 (+73d) | 2010-04-30 → 2010-07-14 (+75d) |  | 52d → 0d | none → 51, 41 |
| 53 | Разработать документацию к Системе. Контакты | 2010-04-26 → 2010-07-15 (+80d) | 2010-04-30 → 2010-07-21 (+82d) |  | 52d → 0d | none → 52, 42 |
| 54 | Разработать документацию к Системе. Синхронизация и удаленный доступ | 2010-04-26 → 2010-06-30 (+65d) | 2010-04-30 → 2010-07-06 (+67d) |  | 52d → 11d | none → 43 |
| 55 | Разработать документацию к Системе. Администрирование и поддержка Системы | 2010-04-26 → 2010-07-15 (+80d) | 2010-04-30 → 2010-07-21 (+82d) |  | 52d → 0d | none → 48, 44 |
| 56 | Подписать Акт сдачи-приемки документации к Системе | 2010-04-26 → 2010-07-22 (+87d) | 2010-04-27 → 2010-07-23 (+87d) |  | 55d → 0d | none → 50, 51, 52, 53, 54, 55 |
| 57 | Резерв времени на разработку документации к Системе | 2010-04-26 → 2010-07-26 (+91d) | 2010-05-21 → 2010-08-20 (+91d) |  | 37d → 0d | none → 56 |
| 58 | Утвердить документацию к Системе на СД | 2010-04-26 → 2010-08-23 (+119d) | 2010-04-30 → 2010-08-27 (+119d) |  | 52d → 0d | none → 57 |
| 59 | Ознакомить пользователей с документацией к Системе | 2010-04-26 → 2010-08-30 (+126d) | 2010-04-30 → 2010-09-03 (+126d) |  | 52d → 0d | none → 58 |
| 60 | Заказчик принял документацию. Пользователи ознакомлены с документацией | 2010-04-26 → 2010-09-03 (+130d) | 2010-04-26 → 2010-09-03 (+130d) |  | 57d → 0d | none → 59 |
| 61 | **Миграция пользователей и настройка клиентских мест** | 2010-04-26 → 2010-06-16 (+51d) | 2010-07-13 → 2010-09-03 (+52d) | 57d → 58d |  |  |
| 62 | Подготовить check-list выполнения миграции пользователей | 2010-04-26 → 2010-06-16 (+51d) | 2010-04-30 → 2010-06-22 (+53d) |  | 52d → 17d | none → 37 |
| 63 | Проверить check-list. Высказать замечания | 2010-04-26 → 2010-06-23 (+58d) | 2010-04-27 → 2010-06-24 (+58d) |  | 55d → 17d | none → 62 |
| 64 | Доработать check-list в соответствии с замечаниями | 2010-04-26 → 2010-06-25 (+60d) | 2010-04-27 → 2010-06-28 (+62d) |  | 55d → 17d | none → 63 |
| 65 | Провести миграцию тестовой группы пользователей | 2010-04-26 → 2010-07-08 (+73d) | 2010-04-30 → 2010-07-14 (+75d) |  | 52d → 10d | none → 64, 46 |
| 66 | Оценить результаты. Доработать check-list | 2010-04-26 → 2010-07-15 (+80d) | 2010-04-27 → 2010-07-16 (+80d) |  | 55d → 10d | none → 65 |
| 67 | Разработать список пользователей к миграции с детализацией до компании | 2010-07-07 → 2010-07-26 (+19d) | 2010-07-13 → 2010-07-30 (+17d) |  |  | none → 1 |
| 68 | Согласовать график проведения миграции с пользователями | 2010-04-26 → 2010-08-02 (+98d) | 2010-04-30 → 2010-08-06 (+98d) |  | 52d → 0d | none → 67, 66, 87 |
| 69 | Обеспечить миграцию топ-менеджеров, УК | 2010-04-26 → 2010-08-09 (+105d) | 2010-04-30 → 2010-08-13 (+105d) |  | 52d → 0d | none → 68 |
| 70 | Подписать акт сдачи-приемки миграции топ-менеджеров и сотрудников УК | 2010-04-26 → 2010-08-13 (+109d) | 2010-04-26 → 2010-08-13 (+109d) |  | 57d → 0d | none → 69 |
| 71 | Обеспечить миграцию пользователей компании А | 2010-04-26 → 2010-08-16 (+112d) | 2010-04-30 → 2010-08-20 (+112d) |  | 52d → 0d | none → 70 |

| ID | Task | Start | Finish | Duration | Total float | Predecessors |
| --- | --- | --- | --- | --- | --- | --- |
| 72 | Подписать акт сдачи-приемки миграции А | 2010-04-26 → 2010-08-20 (+116d) | 2010-04-26 → 2010-08-20 (+116d) |  | 57d → 0d | none → 71 |
| 73 | Обеспечить миграцию пользователей компании Б | 2010-04-26 → 2010-08-23 (+119d) | 2010-04-30 → 2010-08-27 (+119d) |  | 52d → 0d | none → 72 |
| 74 | Подписать акт сдачи-приемки миграции Б | 2010-04-26 → 2010-08-27 (+123d) | 2010-04-26 → 2010-08-27 (+123d) |  | 57d → 0d | none → 73 |
| 75 | Обеспечить миграцию пользователей компании В | 2010-04-26 → 2010-08-30 (+126d) | 2010-04-30 → 2010-09-03 (+126d) |  | 52d → 0d | none → 74 |
| 76 | Подписать акт сдачи-приемки миграции В | 2010-04-26 → 2010-09-03 (+130d) | 2010-04-26 → 2010-09-03 (+130d) |  | 57d → 0d | none → 75 |
| 77 | Обеспечить миграцию пользователей компании Г | 2010-04-26 → 2010-08-09 (+105d) | 2010-04-30 → 2010-08-13 (+105d) |  | 52d → 15d | none → 68 |
| 78 | Подписать акт сдачи-приемки миграции Г | 2010-04-26 → 2010-08-13 (+109d) | 2010-04-26 → 2010-08-13 (+109d) |  | 57d → 15d | none → 77 |
| 79 | Обеспечить миграцию пользователей филиалов | 2010-04-26 → 2010-08-09 (+105d) | 2010-05-07 → 2010-08-20 (+105d) |  | 47d → 10d | none → 68 |
| 80 | Подписать акт сдачи-приемки миграции филиалов | 2010-04-26 → 2010-08-20 (+116d) | 2010-04-26 → 2010-08-20 (+116d) |  | 57d → 10d | none → 79 |
| 81 | Миграция пользователей и настройка клиентских мест завершена | 2010-04-26 → 2010-09-03 (+130d) | 2010-04-26 → 2010-09-03 (+130d) |  | 57d → 0d | none → 80, 78, 76 |
| 82 | **Оборудование** |  | 2010-04-30 → 2010-05-13 (+13d) | 5d → 14d | 52d → 56d |  |
| 83 | Подать заявку на приобретение оборудования |  |  |  | 52d → 56d | none → 1 |
| 84 | Закупить оборудование в соответствии с Заявкой | 2010-04-26 → 2010-05-03 (+7d) | 2010-04-26 → 2010-05-03 (+7d) |  |  | none → 83 |
| 85 | Установить оборудование | 2010-04-26 → 2010-05-04 (+8d) | 2010-04-28 → 2010-05-06 (+8d) |  | 54d → 56d | none → 84 |
| 86 | Настроить и проверить работоспособность оборудование | 2010-04-26 → 2010-05-07 (+11d) | 2010-04-30 → 2010-05-13 (+13d) |  | 52d → 56d | none → 85 |
| 87 | Оборудование приобретено, настроено и проверено | 2010-04-26 → 2010-05-13 (+17d) | 2010-04-26 → 2010-05-13 (+17d) |  | 57d → 56d | none → 86 |
