# Проект "Ребрендинг"

How a schedule from MS Project changed from version to version. A marks actual dates.

## Version 1 (saved 2012-04-28, file Ребрендинг. Расписание проекта (только СДР).mpp)

| ID | WBS | Task | Duration | Start | Finish | Total float |
| --- | --- | --- | --- | --- | --- | --- |
| 1 | 1 | **Разработать описание целевой аудитории** | 5d | 2010-01-04 | 2010-01-08 | 15d |
| 2 |  | Разработать описание целевой аудитории | 5d | 2010-01-04 | 2010-01-08 | 15d |
| 3 |  | Согласовать описание целевой аудитории | 3d | 2010-01-04 | 2010-01-06 | 17d |
| 4 |  | Доработать описание целевой аудитории | 3d | 2010-01-04 | 2010-01-06 | 17d |
| 5 |  | Утвердить описания целевой аудитории | 2d | 2010-01-04 | 2010-01-05 | 18d |
| 6 |  | Описание целевой аудитории утверждено Заказчиком | 0d | 2010-01-04 | 2010-01-04 | 20d |
| 7 | 2 | **Разработать требования к фирменному стилю** | 10d | 2010-01-04 | 2010-01-15 | 10d |
| 8 |  | Разработать требования к фирменному стилю | 5d | 2010-01-04 | 2010-01-08 | 15d |
| 9 |  | Согласовать требования к фирменному стилю | 3d | 2010-01-04 | 2010-01-06 | 17d |
| 10 |  | Доработать требования к фирменному стилю по результатам согласования | 3d | 2010-01-04 | 2010-01-06 | 17d |
| 11 |  | Утвердить требования к фирменному стилю | 2d | 2010-01-04 | 2010-01-05 | 18d |
| 12 |  | Резерв к вехе "Требования к фирменному стилю утверждены" | 5d | 2010-01-04 | 2010-01-08 | 15d |
| 13 |  | Требования к фирменному стилю утверждены Заказчиком | 0d | 2010-01-04 | 2010-01-04 | 20d |
| 14 | 2.7 | **Разработать фирменный стиль** | 10d | 2010-01-04 | 2010-01-15 | 10d |
| 15 |  | Совещание с подрядчиком 1 | 5d | 2010-01-04 | 2010-01-08 | 15d |
| 16 |  | Совещание с подрядчиком 2 | 5d | 2010-01-04 | 2010-01-08 | 15d |
| 17 |  | Совещание с подрядчиком 3 | 5d | 2010-01-04 | 2010-01-08 | 15d |
| 18 |  | Доработать фирменный стиль по результатам встреч | 10d | 2010-01-04 | 2010-01-15 | 10d |
| 19 |  | Утвердить фирменный стиль | 2d | 2010-01-04 | 2010-01-05 | 18d |
| 20 |  | Резерв к вехе "Фирменный стиль утвержден" | 10d | 2010-01-04 | 2010-01-15 | 10d |
| 21 |  | Фирменный стиль утвержден Советом директоров УК | 0d | 2010-01-04 | 2010-01-04 | 20d |
| 22 | 3 | **Разработать web-сайт логистического провайдера** | 20d | 2010-01-04 | 2010-01-29 | 0d |
| 23 | 3.1 | **Разработать Требования к сайту ЛП** | 10d | 2010-01-04 | 2010-01-15 | 10d |
| 24 |  | Разработать Требования к сайту ЛП | 10d | 2010-01-04 | 2010-01-15 | 10d |
| 25 |  | Согласовать Требования к сайту ЛП | 5d | 2010-01-04 | 2010-01-08 | 15d |
| 26 |  | Доработать Требования к сайту ЛП | 3d | 2010-01-04 | 2010-01-06 | 17d |
| 27 |  | Утвердить Требования к сайту ЛП | 2d | 2010-01-04 | 2010-01-05 | 18d |
| 28 |  | Требования к сайту ЛП утверждены Заказчиком | 0d | 2010-01-04 | 2010-01-04 | 20d |
| 29 | 3.2 | **Разработать дизайн сайта** | 20d | 2010-01-04 | 2010-01-29 | 0d |
| 30 |  | Разработать дизайн сайта | 20d | 2010-01-04 | 2010-01-29 | 0d |
| 31 |  | Согласовать дизайн сайта | 1d | 2010-01-04 | 2010-01-04 | 19d |
| 32 |  | Доработать дизайн сайта | 8d | 2010-01-04 | 2010-01-13 | 12d |
| 33 |  | Утвердить дизайн сайта | 3d | 2010-01-04 | 2010-01-06 | 17d |
| 34 |  | Дизайн сайта утвержден Заказчиком | 0d | 2010-01-04 | 2010-01-04 | 20d |
| 35 | 3.3 | **Разработать контент сайта** | 10d | 2010-01-04 | 2010-01-15 | 10d |
| 36 |  | Разработать контент сайта | 10d | 2010-01-04 | 2010-01-15 | 10d |
| 37 |  | Согласовать контент сайта | 3d | 2010-01-04 | 2010-01-06 | 17d |
| 38 |  | Доработать контент сайта | 3d | 2010-01-04 | 2010-01-06 | 17d |
| 39 |  | Утвердить контент сайта | 2d | 2010-01-04 | 2010-01-05 | 18d |
| 40 |  | Отредактировать контент сайта | 5d | 2010-01-04 | 2010-01-08 | 15d |
| 41 |  | Согласование и утверждение отредактированного контента сайта | 5d | 2010-01-04 | 2010-01-08 | 15d |
| 42 |  | Резерв к вехе "Контент сайта согласован и утвержден" | 10d | 2010-01-04 | 2010-01-15 | 10d |
| 43 |  | Контент сайта согласован и утвержден | 0d | 2010-01-04 | 2010-01-04 | 20d |
| 44 | 3.4 | **Программирование и верстка сайта; настройка системы управления контентом** | 20d | 2010-01-04 | 2010-01-29 | 0d |
| 45 |  | Программирование и верстка сайта; настройка системы управления контентом | 20d | 2010-01-04 | 2010-01-29 | 0d |
| 46 | 3.5 | **Провести тестирование и приемку сайта** | 5d | 2010-01-04 | 2010-01-08 | 15d |
| 47 |  | Итерация 1 Провести тестирование сайта пользователям | 2d | 2010-01-04 | 2010-01-05 | 18d |
| 48 |  | Итерация 1 Провести тестирование безопасности сайта | 1d | 2010-01-04 | 2010-01-04 | 19d |
| 49 |  | Итерация 1 Сформировать замечания по результатам тестирования | 1d | 2010-01-04 | 2010-01-04 | 19d |
| 50 |  | Итерация 1 Доработать сайт с учетом замечаний | 5d | 2010-01-04 | 2010-01-08 | 15d |
| 51 |  | Итерация 2 Провести тестирование сайта пользователями | 2d | 2010-01-04 | 2010-01-05 | 18d |
| 52 |  | Итерация 2 Провести тестирование безопасности сайта | 1d | 2010-01-04 | 2010-01-04 | 19d |
| 53 |  | Итерация 2 Сформировать замечания по результатам тестирования | 1d | 2010-01-04 | 2010-01-04 | 19d |
| 54 |  | Итерация 2 Доработать сайт по результатам тестирования | 3d | 2010-01-04 | 2010-01-06 | 17d |
| 55 |  | Осуществить приемку сайта | 1d | 2010-01-04 | 2010-01-04 | 19d |
| 56 |  | Сайт принят | 0d | 2010-01-04 | 2010-01-04 | 20d |
| 57 | 3.6 | **Зарегистрировать доменное имя сайта компании логистического провайдера** | 10d | 2010-01-04 | 2010-01-15 | 10d |
| 58 |  | Разработать варианты доменного имени сайта | 10d | 2010-01-04 | 2010-01-15 | 10d |
| 59 |  | Утвердить доменное имя сайта компании логистического провайдера | 2d | 2010-01-04 | 2010-01-05 | 18d |
| 60 |  | Принять решение о хостинге | 2d | 2010-01-04 | 2010-01-05 | 18d |
| 61 |  | Подать документы на регистрацию доменного имени | 1d | 2010-01-04 | 2010-01-04 | 19d |
| 62 |  | Доменное имя сайта зарегистрировано, хостинг приобретен | 0d | 2010-01-04 | 2010-01-04 | 20d |
| 63 | 3.7 | **Изменить домен электронной почты сотрудников логистического провайдера** | 2d | 2010-01-04 | 2010-01-05 | 18d |
| 64 |  | Изменить домен электронной почты сотрудников логистического провайдера | 2d | 2010-01-04 | 2010-01-05 | 18d |
| 65 |  | Домен электронной почты сотрудников логистического провайдера изменен | 0d | 2010-01-04 | 2010-01-04 | 20d |
| 66 | 3.8 | **Обучить сотрудников работе с сайтом** | 1d | 2010-01-04 | 2010-01-04 | 19d |
| 67 |  | Обучить сотрудников работе с сайтом в соответствии с регламентом поддержки контента сайта | 1d | 2010-01-04 | 2010-01-04 | 19d |
| 68 |  | Сотрудники обучены | 1d | 2010-01-04 | 2010-01-04 | 19d |
| 69 | 4 | **Разработать план продвижения логистического провайдера** | 13d | 2010-01-04 | 2010-01-20 | 7d |
| 70 |  | Разработать план продвижения логистического провайдера | 5d | 2010-01-04 | 2010-01-08 | 15d |

| ID | WBS | Task | Duration | Start | Finish | Total float |
| --- | --- | --- | --- | --- | --- | --- |
| 71 |  | Согласовать план продвижения логистического провайдера | 2d | 2010-01-04 | 2010-01-05 | 18d |
| 72 |  | Доработать план продвижения логистического провайдера | 13d | 2010-01-04 | 2010-01-20 | 7d |
| 73 |  | Утвердить план продвижения логистического провайдера | 1d | 2010-01-04 | 2010-01-04 | 19d |
| 74 |  | План продвижения логистического провайдера утвержден Заказчиком | 0d | 2010-01-04 | 2010-01-04 | 20d |
| 75 | 5 | **Изменить название юридического лица логистического провайдера** | 20d | 2010-01-04 | 2010-01-29 | 0d |
| 76 |  | Оформить протокол Общего Собрания Участников ОДО "АБВ" | 2d | 2010-01-04 | 2010-01-05 | 18d |
| 77 |  | Согласовать новое наименование в управлении юстиции МГИК | 1d | 2010-01-04 | 2010-01-04 | 19d |
| 78 |  | Изготовить новую печать | 3d | 2010-01-04 | 2010-01-06 | 17d |
| 79 |  | Подготовить и зарегистрировать изменения в учредительные документы, уничтожить старую печать | 2d | 2010-01-04 | 2010-01-05 | 18d |
| 80 |  | Уведомить контрагентов | 5d | 2010-01-04 | 2010-01-08 | 15d |
| 81 |  | Внести исправления в документы Единого гос.регистра недвижимого имущества | 2d | 2010-01-04 | 2010-01-05 | 18d |
| 82 |  | Внести изменения в специальные разрешения (лицензии) | 1mo | 2010-01-04 | 2010-01-29 | 0d |
| 83 |  | Внести изменения в Положения о филиалах ОДО "АБВ". Уведомить местные исполнительные органы | 5d | 2010-01-04 | 2010-01-08 | 15d |
| 84 |  | Внести изменения в локальные нормативные акты | 5d | 2010-01-04 | 2010-01-08 | 15d |
| 85 |  | Название юридического лица логистического провайдера изменено. Копия новых учредительных документов передана Заказчику проекта | 0d | 2010-01-04 | 2010-01-04 | 20d |
| 86 | 6 | **Зарегистрировать знак обслуживания** | 12d | 2010-01-04 | 2010-01-19 | 8d |
| 87 |  | Подать заявку на регистрацию знака обслуживания | 2d | 2010-01-04 | 2010-01-05 | 18d |
| 88 |  | Провести предварительную экспертизу знака обслуживания | 0.6mo | 2010-01-04 | 2010-01-19 | 8d |
| 89 |  | Заявка принята к рассмотрению | 0d | 2010-01-04 | 2010-01-04 | 20d |
| 90 | 7 | **Подписать акт приема-передачи результатов проекта от руководителя проекта заказчику** | 2d | 2010-01-04 | 2010-01-05 | 18d |
| 91 |  | Подписать акт приема-передачи результатов проекта от руководителя проекта заказчику | 2d | 2010-01-04 | 2010-01-05 | 18d |
| 92 |  | Акт приема-передачи подписан руководителем проекта и директором ЛП | 0d | 2010-01-04 | 2010-01-04 | 20d |
| 93 |  | Начало проекта | 0d | 2010-01-04 | 2010-01-04 | 20d |
| 94 |  | Проект завершен | 0d | 2010-01-04 | 2010-01-04 | 20d |

## Version 2 (saved 2012-04-28, file Ребрендинг. Расписание проекта (только СДР и ресурсы).mpp)

Last finish stays 2010-01-29.

Changed:

| ID | Task | Total float | Other |
| --- | --- | --- | --- |
| 2 | Разработать описание целевой аудитории |  | resources none → Руководитель проекта |
| 3 | Согласовать описание целевой аудитории |  | resources none → Заказчик |
| 4 | Доработать описание целевой аудитории |  | resources none → Руководитель проекта |
| 5 | Утвердить описания целевой аудитории |  | resources none → Заказчик |
| 8 | Разработать требования к фирменному стилю |  | resources none → Руководитель проекта |
| 9 | Согласовать требования к фирменному стилю |  | resources none → Заказчик; Совет Директоров |
| 10 | Доработать требования к фирменному стилю по результатам согласования |  | resources none → Руководитель проекта |
| 11 | Утвердить требования к фирменному стилю |  | resources none → Руководитель проекта; Заказчик |
| 15 | Совещание с подрядчиком 1 |  | resources none → Руководитель проекта; Заказчик; Подрядчик Фирменный стиль |
| 16 | Совещание с подрядчиком 2 |  | resources none → Руководитель проекта; Заказчик; Подрядчик Фирменный стиль |
| 17 | Совещание с подрядчиком 3 |  | resources none → Руководитель проекта; Заказчик; Подрядчик Фирменный стиль |
| 18 | Доработать фирменный стиль |  | was named Доработать фирменный стиль по результатам встреч; resources none → Подрядчик Фирменный стиль |
| 19 | Утвердить фирменный стиль |  | resources none → Совет Директоров |
| 24 | Разработать Требования к сайту ЛП |  | resources none → Руководитель проекта |
| 25 | Согласовать Требования к сайту ЛП | 15d → 0d | resources none → Заказчик; Специалист ИТ; Совет Директоров |
| 26 | Доработать Требования к сайту ЛП |  | resources none → Руководитель проекта |
| 27 | Утвердить Требования к сайту ЛП |  | resources none → Заказчик |
| 30 | Разработать дизайн сайта |  | resources none → Подрядчик Фирменный стиль |
| 31 | Согласовать дизайн сайта |  | resources none → Заказчик; Специалист ИТ |
| 32 | Доработать дизайн сайта |  | resources none → Подрядчик Фирменный стиль |
| 33 | Утвердить дизайн сайта |  | resources none → Заказчик |
| 36 | Разработать контент сайта |  | resources none → Заказчик |
| 37 | Согласовать контент сайта |  | resources none → Заказчик; Руководитель проекта |
| 38 | Доработать контент сайта |  | resources none → Заказчик |
| 39 | Утвердить контент сайта |  | resources none → Руководитель проекта |
| 40 | Отредактировать контент сайта |  | resources none → Подрядчик Сайт |
| 41 | Согласование и утверждение отредактированного контента сайта |  | resources none → Руководитель проекта |
| 45 | Программирование и верстка сайта; настройка системы управления контентом |  | resources none → Подрядчик Сайт |
| 47 | Итерация 1 Провести тестирование сайта пользователям |  | resources none → Заказчик; Руководитель проекта |
| 48 | Итерация 1 Провести тестирование безопасности сайта |  | resources none → Специалист ИТ |
| 49 | Итерация 1 Сформировать замечания по результатам тестирования |  | resources none → Заказчик; Специалист ИТ |
| 50 | Итерация 1 Доработать сайт с учетом замечаний |  | resources none → Подрядчик Сайт |
| 51 | Итерация 2 Провести тестирование сайта пользователями |  | resources none → Заказчик; Руководитель проекта |
| 52 | Итерация 2 Провести тестирование безопасности сайта |  | resources none → Специалист ИТ |
| 53 | Итерация 2 Сформировать замечания по результатам тестирования |  | resources none → Заказчик; Специалист ИТ |
| 54 | Итерация 2 Доработать сайт по результатам тестирования |  | resources none → Подрядчик Сайт |
| 55 | Осуществить приемку сайта |  | resources none → Заказчик; Руководитель проекта |
| 58 | Разработать варианты доменного имени сайта |  | resources none → Руководитель проекта |
| 59 | Утвердить доменное имя сайта компании логистического провайдера |  | resources none → Заказчик |
| 60 | Принять решение о хостинге |  | resources none → Руководитель проекта; Специалист ИТ |
| 61 | Подать документы на регистрацию доменного имени |  | resources none → Специалист ИТ |
| 64 | Изменить домен электронной почты сотрудников логистического провайдера |  | resources none → Специалист ИТ |
| 70 | Разработать план продвижения логистического провайдера |  | resources none → Руководитель проекта |
| 71 | Согласовать план продвижения логистического провайдера |  | resources none → Заказчик; Руководитель проекта |
| 72 | Доработать план продвижения логистического провайдера |  | resources none → Руководитель проекта |
| 73 | Утвердить план продвижения логистического провайдера |  | resources none → Заказчик |
| 76 | Оформить протокол Общего Собрания Участников ОДО "АБВ" |  | resources none → Юрист |
| 77 | Согласовать новое наименование в управлении юстиции МГИК |  | resources none → Юрист |
| 78 | Изготовить новую печать |  | resources none → Юрист |
| 79 | Подготовить и зарегистрировать изменения в учредительные документы, уничтожить старую печать |  | resources none → Юрист |
| 80 | Уведомить контрагентов |  | resources none → Юрист |
| 81 | Внести исправления в документы Единого гос.регистра недвижимого имущества |  | resources none → Юрист |
| 82 | Внести изменения в специальные разрешения (лицензии) |  | resources none → Юрист |
| 83 | Внести изменения в Положения о филиалах ОДО "АБВ". Уведомить местные исполнительные органы |  | resources none → Юрист |
| 84 | Внести изменения в локальные нормативные акты |  | resources none → Юрист |
| 87 | Подать заявку на регистрацию знака обслуживания |  | resources none → Юрист |
| 88 | Провести предварительную экспертизу знака обслуживания |  | resources none → Юрист |
| 91 | Подписать акт приема-передачи результатов проекта от руководителя проекта заказчику |  | resources none → Руководитель проекта; Заказчик |

## Version 3 (saved 2012-04-28, file Ребрендинг. Расписание проекта (только СДР, ресурсы, связи).mpp)

Last finish 2010-01-29 → 2010-07-13 (+165d).

Changed:

| ID | Task | Start | Finish | Duration | Total float | Predecessors | Other |
| --- | --- | --- | --- | --- | --- | --- | --- |
| 1 | **Разработать описание целевой аудитории** |  | 2010-01-08 → 2010-01-20 (+12d) | 5d → 13d | 15d → 0d |  |  |
| 2 | Разработать описание целевой аудитории |  |  |  | 15d → 0d | none → 93 |  |
| 3 | Согласовать описание целевой аудитории | 2010-01-04 → 2010-01-11 (+7d) | 2010-01-06 → 2010-01-13 (+7d) |  | 17d → 0d | none → 2 |  |
| 4 | Доработать описание целевой аудитории | 2010-01-04 → 2010-01-14 (+10d) | 2010-01-06 → 2010-01-18 (+12d) |  | 17d → 0d | none → 3 |  |
| 5 | Утвердить описания целевой аудитории | 2010-01-04 → 2010-01-19 (+15d) | 2010-01-05 → 2010-01-20 (+15d) |  | 18d → 0d | none → 4 |  |
| 6 | Описание целевой аудитории утверждено Заказчиком | 2010-01-04 → 2010-01-20 (+16d) | 2010-01-04 → 2010-01-20 (+16d) |  | 20d → 0d | none → 5 |  |
| 7 | **Разработать требования к фирменному стилю** | 2010-01-04 → 2010-01-21 (+17d) | 2010-01-15 → 2010-04-07 (+82d) | 10d → 55d | 10d → 0d |  |  |
| 8 | Разработать требования к фирменному стилю | 2010-01-04 → 2010-01-21 (+17d) | 2010-01-08 → 2010-01-27 (+19d) |  | 15d → 0d | none → 6 |  |
| 9 | Согласовать требования к фирменному стилю | 2010-01-04 → 2010-01-28 (+24d) | 2010-01-06 → 2010-02-01 (+26d) |  | 17d → 0d | none → 8 |  |
| 10 | Доработать требования к фирменному стилю по результатам согласования | 2010-01-04 → 2010-02-02 (+29d) | 2010-01-06 → 2010-02-04 (+29d) |  | 17d → 0d | none → 9 |  |
| 11 | Утвердить требования к фирменному стилю | 2010-01-04 → 2010-02-05 (+32d) | 2010-01-05 → 2010-02-08 (+34d) |  | 18d → 0d | none → 10 |  |
| 12 | Резерв к вехе "Требования к фирменному стилю утверждены" | 2010-01-04 → 2010-02-09 (+36d) | 2010-01-08 → 2010-02-15 (+38d) |  | 15d → 0d | none → 11 |  |
| 13 | Требования к фирменному стилю утверждены Заказчиком | 2010-01-04 → 2010-02-15 (+42d) | 2010-01-04 → 2010-02-15 (+42d) |  | 20d → 0d | none → 12 |  |
| 14 | **Разработать фирменный стиль** | 2010-01-04 → 2010-02-16 (+43d) | 2010-01-15 → 2010-04-07 (+82d) | 10d → 37d | 10d → 0d |  |  |
| 15 | Совещание с подрядчиком 1 | 2010-01-04 → 2010-02-16 (+43d) | 2010-01-08 → 2010-02-22 (+45d) |  | 15d → 0d | none → 13 | resources Руководитель проекта; Заказчик; Подрядчик Фирменный стиль → Руководитель проекта; Заказчик; Подрядчик ФС |
| 16 | Совещание с подрядчиком 2 | 2010-01-04 → 2010-02-23 (+50d) | 2010-01-08 → 2010-03-01 (+52d) |  | 15d → 0d | none → 15 | resources Руководитель проекта; Заказчик; Подрядчик Фирменный стиль → Руководитель проекта; Заказчик; Подрядчик ФС |
| 17 | Совещание с подрядчиком 3 | 2010-01-04 → 2010-03-02 (+57d) | 2010-01-08 → 2010-03-08 (+59d) |  | 15d → 0d | none → 16 | resources Руководитель проекта; Заказчик; Подрядчик Фирменный стиль → Руководитель проекта; Заказчик; Подрядчик ФС |
| 18 | Доработать фирменный стиль | 2010-01-04 → 2010-03-09 (+64d) | 2010-01-15 → 2010-03-22 (+66d) |  | 10d → 0d | none → 17 | resources Подрядчик Фирменный стиль → Подрядчик ФС |
| 19 | Утвердить фирменный стиль | 2010-01-04 → 2010-03-23 (+78d) | 2010-01-05 → 2010-03-24 (+78d) |  | 18d → 0d | none → 18 |  |
| 20 | Резерв к вехе "Фирменный стиль утвержден" | 2010-01-04 → 2010-03-25 (+80d) | 2010-01-15 → 2010-04-07 (+82d) |  | 10d → 0d | none → 19 |  |
| 21 | Фирменный стиль утвержден Советом директоров УК | 2010-01-04 → 2010-04-07 (+93d) | 2010-01-04 → 2010-04-07 (+93d) |  | 20d → 0d | none → 20 |  |
| 22 | **Разработать web-сайт логистического провайдера** | 2010-01-04 A | 2010-01-29 → 2010-07-09 (+161d) | 20d → 135d | 0d → 2d |  |  |
| 23 | **Разработать Требования к сайту ЛП** | 2010-01-04 → 2010-02-16 A (+43d) | 2010-01-15 → 2010-03-15 (+59d) | 10d → 20d | 0d → 7d |  |  |
| 24 | Разработать Требования к сайту ЛП | 2010-01-04 → 2010-02-16 (+43d) | 2010-01-15 → 2010-03-01 (+45d) |  | 10d → 7d | none → 13 |  |
| 25 | Согласовать Требования к сайту ЛП | 2010-01-04 → 2010-03-01 A (+56d) | 2010-01-08 → 2010-03-08 (+59d) |  | 0d → 7d | none → 24 |  |
| 26 | Доработать Требования к сайту ЛП | 2010-01-04 → 2010-03-09 (+64d) | 2010-01-06 → 2010-03-11 (+64d) |  | 17d → 7d | none → 25 |  |
| 27 | Утвердить Требования к сайту ЛП | 2010-01-04 → 2010-03-12 (+67d) | 2010-01-05 → 2010-03-15 (+69d) |  | 18d → 7d | none → 26 |  |
| 28 | Требования к сайту ЛП утверждены Заказчиком | 2010-01-04 → 2010-03-15 (+70d) | 2010-01-04 → 2010-03-15 (+70d) |  | 20d → 7d | none → 27 |  |
| 29 | **Разработать дизайн сайта** | 2010-01-04 → 2010-04-08 (+94d) | 2010-01-29 → 2010-05-21 (+112d) | 20d → 32d |  |  |  |
| 30 | Разработать дизайн сайта | 2010-01-04 → 2010-04-08 (+94d) | 2010-01-29 → 2010-05-05 (+96d) |  |  | none → 21, 28, 36 | resources Подрядчик Фирменный стиль → Подрядчик ФС |
| 31 | Согласовать дизайн сайта | 2010-01-04 → 2010-05-06 (+122d) | 2010-01-04 → 2010-05-06 (+122d) |  | 19d → 0d | none → 30 |  |
| 32 | Доработать дизайн сайта | 2010-01-04 → 2010-05-07 (+123d) | 2010-01-13 → 2010-05-18 (+125d) |  | 12d → 0d | none → 31 | resources Подрядчик Фирменный стиль → Подрядчик ФС |
| 33 | Утвердить дизайн сайта | 2010-01-04 → 2010-05-19 (+135d) | 2010-01-06 → 2010-05-21 (+135d) |  | 17d → 0d | none → 32 |  |
| 34 | Дизайн сайта утвержден Заказчиком | 2010-01-04 → 2010-05-21 (+137d) | 2010-01-04 → 2010-05-21 (+137d) |  | 20d → 0d | none → 33 |  |
| 35 | **Разработать контент сайта** | 2010-01-04 → 2010-03-16 (+71d) | 2010-01-15 → 2010-06-15 (+151d) | 10d → 66d | 10d → 7d |  |  |
| 36 | Разработать контент сайта | 2010-01-04 → 2010-03-16 (+71d) | 2010-01-15 → 2010-03-29 (+73d) |  | 10d → 7d | none → 28 |  |
| 37 | Согласовать контент сайта | 2010-01-04 → 2010-05-07 (+123d) | 2010-01-06 → 2010-05-11 (+125d) |  | 17d → 18d | none → 36, 31 |  |
| 38 | Доработать контент сайта | 2010-01-04 → 2010-05-12 (+128d) | 2010-01-06 → 2010-05-14 (+128d) |  | 17d → 18d | none → 37 |  |
| 39 | Утвердить контент сайта | 2010-01-04 → 2010-05-17 (+133d) | 2010-01-05 → 2010-05-18 (+133d) |  |  | none → 38 |  |
| 40 | Отредактировать контент сайта | 2010-01-04 → 2010-05-19 (+135d) | 2010-01-08 → 2010-05-25 (+137d) |  | 15d → 18d | none → 39 |  |
| 41 | Согласование и утверждение отредактированного контента сайта | 2010-01-04 → 2010-05-26 (+142d) | 2010-01-08 → 2010-06-01 (+144d) |  | 15d → 18d | none → 40 |  |
| 42 | Резерв к вехе "Контент сайта согласован и утвержден" | 2010-01-04 → 2010-06-02 (+149d) | 2010-01-15 → 2010-06-15 (+151d) |  | 10d → 18d | none → 41 |  |
| 43 | Контент сайта согласован и утвержден | 2010-01-04 → 2010-06-15 (+162d) | 2010-01-04 → 2010-06-15 (+162d) |  | 20d → 18d | none → 42 |  |
| 44 | **Программирование и верстка сайта; настройка системы управления контентом** | 2010-01-04 → 2010-05-24 (+140d) | 2010-01-29 → 2010-06-18 (+140d) |  |  |  |  |
| 45 | Программирование и верстка сайта; настройка системы управления контентом | 2010-01-04 → 2010-05-24 (+140d) | 2010-01-29 → 2010-06-18 (+140d) |  |  | none → 34 |  |
| 46 | **Провести тестирование и приемку сайта** | 2010-01-04 → 2010-06-21 (+168d) | 2010-01-08 → 2010-07-09 (+182d) | 5d → 15d | 15d → 0d |  |  |
| 47 | Итерация 1 Провести тестирование сайта пользователям | 2010-01-04 → 2010-06-21 (+168d) | 2010-01-05 → 2010-06-22 (+168d) |  | 18d → 0d | none → 45 |  |
| 48 | Итерация 1 Провести тестирование безопасности сайта | 2010-01-04 → 2010-06-21 (+168d) | 2010-01-04 → 2010-06-21 (+168d) |  | 19d → 1d | none → 45 |  |
| 49 | Итерация 1 Сформировать замечания по результатам тестирования | 2010-01-04 → 2010-06-23 (+170d) | 2010-01-04 → 2010-06-23 (+170d) |  | 19d → 0d | none → 47, 48 |  |
| 50 | Итерация 1 Доработать сайт с учетом замечаний | 2010-01-04 → 2010-06-24 (+171d) | 2010-01-08 → 2010-06-30 (+173d) |  | 15d → 0d | none → 49 |  |
| 51 | Итерация 2 Провести тестирование сайта пользователями | 2010-01-04 → 2010-07-01 (+178d) | 2010-01-05 → 2010-07-02 (+178d) |  | 18d → 0d | none → 50 |  |
| 52 | Итерация 2 Провести тестирование безопасности сайта | 2010-01-04 → 2010-07-01 (+178d) | 2010-01-04 → 2010-07-01 (+178d) |  | 19d → 1d | none → 50 |  |
| 53 | Итерация 2 Сформировать замечания по результатам тестирования | 2010-01-04 → 2010-07-05 (+182d) | 2010-01-04 → 2010-07-05 (+182d) |  | 19d → 0d | none → 52, 51 |  |
| 54 | Итерация 2 Доработать сайт по результатам тестирования | 2010-01-04 → 2010-07-06 (+183d) | 2010-01-06 → 2010-07-08 (+183d) |  | 17d → 0d | none → 53 |  |
| 55 | Осуществить приемку сайта | 2010-01-04 → 2010-07-09 (+186d) | 2010-01-04 → 2010-07-09 (+186d) |  | 19d → 0d | none → 54 |  |
| 56 | Сайт принят | 2010-01-04 → 2010-07-09 (+186d) | 2010-01-04 → 2010-07-09 (+186d) |  | 20d → 0d | none → 55, 43, 62 |  |
| 57 | **Зарегистрировать доменное имя сайта компании логистического провайдера** | 2010-01-04 → 2010-03-16 (+71d) | 2010-01-15 → 2010-04-05 (+80d) | 10d → 15d | 10d → 69d |  |  |
| 58 | Разработать варианты доменного имени сайта | 2010-01-04 → 2010-03-16 (+71d) | 2010-01-15 → 2010-03-29 (+73d) |  | 10d → 69d | none → 28 |  |
| 59 | Утвердить доменное имя сайта компании логистического провайдера | 2010-01-04 → 2010-03-30 (+85d) | 2010-01-05 → 2010-03-31 (+85d) |  | 18d → 69d | none → 58 |  |
| 60 | Принять решение о хостинге | 2010-01-04 → 2010-04-01 (+87d) | 2010-01-05 → 2010-04-02 (+87d) |  | 18d → 69d | none → 59 |  |
| 61 | Подать документы на регистрацию доменного имени | 2010-01-04 → 2010-04-05 (+91d) | 2010-01-04 → 2010-04-05 (+91d) |  | 19d → 69d | none → 60 |  |
| 62 | Доменное имя сайта зарегистрировано, хостинг приобретен | 2010-01-04 → 2010-04-05 (+91d) | 2010-01-04 → 2010-04-05 (+91d) |  | 20d → 69d | none → 61 |  |
| 63 | **Изменить домен электронной почты сотрудников логистического провайдера** | 2010-01-04 → 2010-04-06 (+92d) | 2010-01-05 → 2010-04-07 (+92d) |  | 18d → 69d |  |  |
| 64 | Изменить домен электронной почты сотрудников логистического провайдера | 2010-01-04 → 2010-04-06 (+92d) | 2010-01-05 → 2010-04-07 (+92d) |  | 18d → 69d | none → 61, 62 |  |
| 65 | Домен электронной почты сотрудников логистического провайдера изменен | 2010-01-04 → 2010-04-07 (+93d) | 2010-01-04 → 2010-04-07 (+93d) |  | 20d → 69d | none → 64 |  |
| 66 | **Обучить сотрудников работе с сайтом** |  | 2010-01-04 → 2010-01-05 (+1d) | 1d → 2d | 19d → 135d |  |  |
| 68 | Сотрудники обучены | 2010-01-04 → 2010-01-05 (+1d) | 2010-01-04 → 2010-01-05 (+1d) |  | 19d → 135d | none → 67 |  |
| 69 | **Разработать план продвижения логистического провайдера** |  | 2010-01-20 → 2010-02-01 (+12d) | 13d → 21d | 7d → 114d |  |  |
| 71 | Согласовать план продвижения логистического провайдера | 2010-01-04 → 2010-01-11 (+7d) | 2010-01-05 → 2010-01-12 (+7d) |  | 18d → 114d | none → 70 |  |
| 72 | Доработать план продвижения логистического провайдера | 2010-01-04 → 2010-01-13 (+9d) | 2010-01-20 → 2010-01-29 (+9d) |  | 7d → 114d | none → 71 |  |

| ID | Task | Start | Finish | Duration | Total float | Predecessors |
| --- | --- | --- | --- | --- | --- | --- |
| 73 | Утвердить план продвижения логистического провайдера | 2010-01-04 → 2010-02-01 (+28d) | 2010-01-04 → 2010-02-01 (+28d) |  | 19d → 114d | none → 72 |
| 74 | План продвижения логистического провайдера утвержден Заказчиком | 2010-01-04 → 2010-02-01 (+28d) | 2010-01-04 → 2010-02-01 (+28d) |  | 20d → 114d | none → 73 |
| 75 | **Изменить название юридического лица логистического провайдера** | 2010-01-04 → 2010-04-08 (+94d) | 2010-01-29 → 2010-05-17 (+108d) | 20d → 28d | 0d → 39d |  |
| 76 | Оформить протокол Общего Собрания Участников ОДО "АБВ" | 2010-01-04 → 2010-04-08 (+94d) | 2010-01-05 → 2010-04-09 (+94d) |  | 18d → 39d | none → 21 |
| 77 | Согласовать новое наименование в управлении юстиции МГИК | 2010-01-04 → 2010-04-12 (+98d) | 2010-01-04 → 2010-04-12 (+98d) |  | 19d → 39d | none → 76 |
| 78 | Изготовить новую печать | 2010-01-04 → 2010-04-13 (+99d) | 2010-01-06 → 2010-04-15 (+99d) |  | 17d → 39d | none → 77 |
| 79 | Подготовить и зарегистрировать изменения в учредительные документы, уничтожить старую печать | 2010-01-04 → 2010-04-16 (+102d) | 2010-01-05 → 2010-04-19 (+104d) |  | 18d → 39d | none → 78 |
| 80 | Уведомить контрагентов | 2010-01-04 → 2010-04-20 (+106d) | 2010-01-08 → 2010-04-26 (+108d) |  | 15d → 52d | none → 79 |
| 81 | Внести исправления в документы Единого гос.регистра недвижимого имущества | 2010-01-04 → 2010-04-27 (+113d) | 2010-01-05 → 2010-04-28 (+113d) |  | 18d → 52d | none → 80 |
| 82 | Внести изменения в специальные разрешения (лицензии) | 2010-01-04 → 2010-04-20 (+106d) | 2010-01-29 → 2010-05-17 (+108d) |  | 0d → 39d | none → 79 |
| 83 | Внести изменения в Положения о филиалах ОДО "АБВ". Уведомить местные исполнительные органы | 2010-01-04 → 2010-04-20 (+106d) | 2010-01-08 → 2010-04-26 (+108d) |  | 15d → 49d | none → 79 |
| 84 | Внести изменения в локальные нормативные акты | 2010-01-04 → 2010-04-27 (+113d) | 2010-01-08 → 2010-05-03 (+115d) |  | 15d → 49d | none → 83 |
| 85 | Название юридического лица логистического провайдера изменено. Копия новых учредительных документов передана Заказчику проекта | 2010-01-04 → 2010-05-17 (+133d) | 2010-01-04 → 2010-05-17 (+133d) |  | 20d → 39d | none → 77, 78, 79, 80, 81, 82, 83, 84 |
| 86 | **Зарегистрировать знак обслуживания** | 2010-01-04 → 2010-04-08 (+94d) | 2010-01-19 → 2010-04-27 (+98d) | 12d → 14d | 8d → 53d |  |
| 87 | Подать заявку на регистрацию знака обслуживания | 2010-01-04 → 2010-04-08 (+94d) | 2010-01-05 → 2010-04-09 (+94d) |  | 18d → 53d | none → 21 |
| 88 | Провести предварительную экспертизу знака обслуживания | 2010-01-04 → 2010-04-12 (+98d) | 2010-01-19 → 2010-04-27 (+98d) |  | 8d → 53d | none → 87 |
| 89 | Заявка принята к рассмотрению | 2010-01-04 → 2010-04-27 (+113d) | 2010-01-04 → 2010-04-27 (+113d) |  | 20d → 53d | none → 88 |
| 90 | **Подписать акт приема-передачи результатов проекта от руководителя проекта заказчику** | 2010-01-04 → 2010-07-12 (+189d) | 2010-01-05 → 2010-07-13 (+189d) |  | 18d → 0d |  |
| 91 | Подписать акт приема-передачи результатов проекта от руководителя проекта заказчику | 2010-01-04 → 2010-07-12 (+189d) | 2010-01-05 → 2010-07-13 (+189d) |  | 18d → 0d | none → 6, 21, 56, 74, 85, 89 |
| 92 | Акт приема-передачи подписан руководителем проекта и директором ЛП | 2010-01-04 → 2010-07-13 (+190d) | 2010-01-04 → 2010-07-13 (+190d) |  | 20d → 0d | none → 91 |
| 94 | Проект завершен | 2010-01-04 → 2010-07-13 (+190d) | 2010-01-04 → 2010-07-13 (+190d) |  | 20d → 0d | none → 92, 68, 65 |
